# ImportTaskCplan

Schedule from MS Project, 2007-09-01 to 2008-06-02, costs in $.
CMV INGENIERIA EU

## Calendars

- Estándar: Mon-Fri 09:00-13:00, 15:00-19:00; Sat-Sun off.

## Resources

| Resource |
| --- |
| DIRECTOR DE OBRA |
| PROGRAMADOR |
| AYUDANTE |
| OFICIAL |
| CADENERO |
| TOPOGRAFO |

## Schedule

| ID | WBS | Task | Type | Duration | Start | Finish | Predecessors | Total slack | Free slack | Resources | Work | Cost | Text4 | Text5 | Text2 | Text1 |
| --- | --- | --- | --- | --- | --- | --- | --- | --- | --- | --- | --- | --- | --- | --- | --- | --- |
| 1 | 1 | inicio | milestone | 0d | 2007-09-01 | 2007-09-01 |  | 0d |  |  |  |  |  |  |  |  |
| 2 | 2 | **PRELIMINARES** |  | 20d | 2007-09-03 | 2007-09-28 |  | 0d |  |  | 1410.4h | 34,597,376 | 01 | 01 |  |  |
| 3 | 2.1 | **PRELIMINARES** |  | 20d | 2007-09-03 | 2007-09-28 |  | 0d |  |  | 1410.4h | 34,597,376 | 01 | 01.01 | 1.1 |  |
| 4 | 2.1.1 | Planeación de obra |  | 0.5mo | 2007-09-03 | 2007-09-14 | 1 | 0d |  | DIRECTOR DE OBRA; PROGRAMADOR | 160h | 2,350,000 | 01 | 01.01 | 1.1.1 | gl |
| 5 | 2 | INICIO | milestone | 0d | 2007-09-17 | 2007-09-17 | 4 | 0d |  |  |  |  |  |  |  |  |
| 6 | 2.1.3 | Replanteo - localizacion - hiladeros |  | 0.5mo | 2007-09-17 | 2007-09-28 | 4 | 0.24d | 0d | AYUDANTE [200%]; CADENERO [400%]; TOPOGRAFO [200%] | 640h | 6,057,320 | 01 | 01.01 | 1.1.2 | gl |
| 7 | 2.1.4 | Demolicion andenes y retiro |  | 3d | 2007-09-17 | 2007-09-19 | 4 | 182.08d | 0d | AYUDANTE; OFICIAL | 48h | 370,395 | 01 | 01.01 | 1.1.3 | m2 |
| 8 | 2.1.5 | Demolicion y reposición pavimento asfaltico (incluye corte con disco diamantado) |  | 0.5d | 2007-09-20 | 2007-09-20 | 7 | 182.08d |  | AYUDANTE; OFICIAL | 8h | 282,464 | 01 | 01.01 | 1.1.4 | m2 |
| 9 | 2.1.6 | Cerramiento en tela h=2.1 |  | 4.65d | 2007-09-17 | 2007-09-21 | 4 | 180.93d |  | AYUDANTE; OFICIAL | 74.4h | 2,658,312 | 01 | 01.01 | 1.1.5 | ml |
| 10 | 2.1.7 | Campamento de obra |  | 5d | 2007-09-17 | 2007-09-21 | 4 | 180.58d |  | AYUDANTE [800%]; OFICIAL [400%] | 480h | 22,878,885 | 01 | 01.01 | 1.1.6 | gl |
| 11 | 3 | **CIMENTACION** |  | 57.09d | 2007-09-24 | 2007-12-12 |  | 0.24d |  |  | 9557.04h | 285,528,447 | 02 | 02 |  |  |
| 12 | 3.1 | **CIMENTACION** |  | 57.09d | 2007-09-24 | 2007-12-12 |  | 0.24d |  |  | 9557.04h | 285,528,447 | 02 | 02.01 | 2.1 |  |
| 13 | 3.1.1 | Excavacion en tierra hasta 3 mts. |  | 10.2d | 2007-09-24 | 2007-10-08 | 6FS-5% | 0.53d | 0d | AYUDANTE [1000%] | 816h | 9,826,300 | 02 | 02.01 | 2.1.1 | m3 |
| 14 | 3.1.2 | Excavación mecánica |  | 3.9d | 2007-09-24 | 2007-09-27 | 6FS-5% | 0.24d | 0d | AYUDANTE [200%] | 62.4h | 2,149,680 | 02 | 02.01 | 2.1.2 | m3 |
| 15 | 3.1.3 | Excavación en basura |  | 3.52d | 2007-09-27 | 2007-10-03 | 14 | 0.24d | 0d | AYUDANTE [300%] | 84.56h | 1,105,227 | 02 | 02.01 | 2.1.3 | m3 |
| 16 | 3.1.4 | Afirmado |  | 5.4d | 2007-11-12 | 2007-11-19 | 17 | 37.74d | 0d | AYUDANTE [300%] | 129.6h | 2,517,723 | 02 | 02.01 | 2.1.4 | m3 |
| 17 | 3.1.5 | Lleno con material seleccionado de excavacion |  | 19.1d | 2007-10-16 | 2007-11-12 | 21FS-9% | 37.74d | 0d | AYUDANTE [500%] | 764h | 9,220,716 | 02 | 02.01 | 2.1.5 | m3 |
| 18 | 3.1.6 | Retiro de sobrantes |  | 20.5d | 2007-10-16 | 2007-11-13 | 21FS-9% | 143.91d |  | AYUDANTE | 164h | 7,424,280 | 02 | 02.01 | 2.1.6 | m3 |
| 19 | 3.1.7 | Concreto 14mpa solados |  | 11.6d | 2007-10-03 | 2007-10-19 | 15, 13FS-3% | 0.24d | 0d | AYUDANTE [300%]; OFICIAL | 371.2h | 5,696,963 | 02 | 02.01 | 2.1.7 | m3 |
| 20 | 3.1.8 | Concreto 24.5mpa dados |  | 14.7d | 2007-10-04 | 2007-10-25 | 19FS-9% | 0.24d | 0d | AYUDANTE; OFICIAL | 235.2h | 7,196,511 | 02 | 02.01 | 2.1.8 | m3 |
| 21 | 3.1.9 | Concreto 24.5mpa viga de fundacion |  | 30.1d | 2007-10-11 | 2007-11-22 | 22FS-9% | 0.24d | 0d | AYUDANTE; OFICIAL | 481.6h | 14,269,679 | 02 | 02.01 | 2.1.9 | m3 |
| 22 | 3.1.10 | Concreto 24.5mpa zapatas |  | 31.02d | 2007-10-08 | 2007-11-20 | 20FS-9% | 0.24d | 0d | AYUDANTE [500%]; CADENERO [500%] | 2481.6h | 92,632,488 | 02 | 02.01 | 2.1.10 | m3 |
| 23 | 3.1.11 | Losa de contrapiso e=0.10 m. |  | 13.83d | 2007-11-22 | 2007-12-12 | 16, 21 | 123.49d |  | AYUDANTE [300%]; OFICIAL [300%] | 663.84h | 19,365,970 | 02 | 02.01 | 2.1.11 | m2 |
| 24 | 3.1.12 | Concreto 24.5 mpa tanque de almacenamiento |  | 18.73d | 2007-10-03 | 2007-10-30 | 15 | 146.92d | 0d | AYUDANTE [300%]; OFICIAL [300%] | 899.2h | 22,035,041 | 02 | 02.01 | 2.1.12 | m3 |
| 25 | 3.1.13 | Impermeabilizacion muro con tela asfaltica |  | 3.43d | 2007-10-30 | 2007-11-02 | 24 | 150.99d |  | AYUDANTE; OFICIAL | 54.88h | 935,616 | 02 | 02.01 | 2.1.13 | m2 |
| 26 | 3.1.14 | Tuberia filtro 100mm con tela filtro |  | 2.46d | 2007-10-30 | 2007-11-01 | 24 | 151.96d |  | AYUDANTE [50%]; OFICIAL [50%] | 19.68h | 1,017,093 | 02 | 02.01 | 2.1.14 | ml |
| 27 | 3.1.15 | Geotextil no tejido 1600 |  | 7.5d | 2007-10-30 | 2007-11-08 | 24 | 146.92d |  | AYUDANTE [10%] | 6h | 359,899 | 02 | 02.01 | 2.1.15 | m2 |
| 28 | 3.1.16 | Filtro en gravilla limpia |  | 0.9d | 2007-10-30 | 2007-10-31 | 24 | 153.52d |  | AYUDANTE; OFICIAL | 14.4h | 768,708 | 02 | 02.01 | 2.1.16 | m3 |
| 29 | 3.1.17 | Acero refuerzo 420mpa |  | 28.86d | 2007-10-03 | 2007-11-13 | 15 | 144.29d |  | AYUDANTE [1000%] | 2308.88h | 89,006,553 | 02 | 02.01 | 2.1.17 | kg |

| ID | WBS | Task | Duration | Start | Finish | Predecessors | Total slack | Free slack | Resources | Work | Cost | Text4 | Text5 | Text2 | Text1 |
| --- | --- | --- | --- | --- | --- | --- | --- | --- | --- | --- | --- | --- | --- | --- | --- |
| 30 | 4 | **ESTRUCTURA** | 107.08d | 2007-11-22 | 2008-04-21 |  | 0.24d |  |  | 21563.2h | 725,040,540 | 03 | 03 |  |  |
| 31 | 4.1 | **ESTRUCTURA** | 107.08d | 2007-11-22 | 2008-04-21 |  | 0.24d |  |  | 21563.2h | 725,040,540 | 03 | 03.01 | 3.1 |  |
| 32 | 4.1.1 | Concreto 24.5 mpa columnas rectangulares a la vista lisas | 72.38d | 2007-11-22 | 2008-03-03 | 21 | 0.24d | 0d | AYUDANTE [500%]; OFICIAL [500%] | 5790.4h | 153,385,722 | 03 | 03.01 | 3.1.1 | m3 |
| 33 | 4.1.2 | Concreto 24.5mpa viga elevada a la vista lisa | 70.4d | 2007-12-03 | 2008-03-10 | 32FS-9% | 0.24d | 0d | AYUDANTE; OFICIAL | 1126.4h | 30,344,768 | 03 | 03.01 | 3.1.2 | m3 |
| 34 | 4.1.3 | Concreto 24.5mpa viga canal | 5.5d | 2008-03-10 | 2008-03-18 | 33 | 54.18d |  | AYUDANTE; OFICIAL | 88h | 2,342,215 | 03 | 03.01 | 3.1.3 | m3 |
| 35 | 4.1.4 | Concreto 24.5 mpa losa lamina colaborante a la vista lisa | 75.24d | 2007-12-12 | 2008-03-26 | 33FS-9% | 0.24d | 0d | AYUDANTE [609%]; OFICIAL [228%] | 5036.41h | 198,860,604 | 03 | 03.01 | 3.1.4 | m2 |
| 36 | 4.1.5 | Malla electrosoldada 15x15 5mm | 72.83d | 2007-12-10 | 2008-03-20 | 35SS-2d | 52.21d |  | AYUDANTE [12%]; OFICIAL [12%] | 139.84h | 21,482,373 | 03 | 03.01 | 3.1.5 | m2 |
| 37 | 4.1.6 | Alfajía en concreto para antepechos y ventaneria | 44.91d | 2008-02-11 | 2008-04-14 | 56FS-9% | 35.01d |  | AYUDANTE; OFICIAL | 718.56h | 8,427,971 | 03 | 03.01 | 3.1.6 |  |
| 38 | 4.1.7 | Anden en concreto | 1.39d | 2008-04-17 | 2008-04-21 | 220 | 30.24d | 30d | AYUDANTE; OFICIAL | 22.24h | 733,250 | 03 | 03.01 | 3.1.7 | m2 |
| 39 | 4.1.8 | Acero refuerzo 420mpa | 88.57d | 2007-11-22 | 2008-03-25 | 32SS | 48.75d |  | AYUDANTE [1000%] | 7085.92h | 273,162,987 | 03 | 03.01 | 3.1.8 | kg |
| 40 | 4.1.9 | Concreto a la vista, placa escalas incluye vigas y descolgados fc 24.5 mpa | 62.51d | 2008-01-01 | 2008-03-28 | 33FS-7% | 46.45d |  | AYUDANTE [160%]; OFICIAL | 1300.21h | 31,242,200 | 03 | 03.01 | 3.1.9 | m² |
| 41 | 4.1.10 | Concreto placas macizas espesos 0.15 concreto fc 24.5 mpa | 76.69d | 2008-01-01 | 2008-04-17 | 33FS-7% | 32.28d |  | OFICIAL [16%]; AYUDANTE [26%] | 255.22h | 5,058,450 | 03 | 03.01 | 3.1.10 | m² |
| 42 | 5 | **CUBIERTA Y ESTRUCTURAS METÁLICAS** | 47.56d | 2008-03-26 | 2008-06-02 |  | 0.24d |  |  | 5798.72h | 253,340,990 | 04 | 04 |  |  |
| 43 | 5.1 | **CUBIERTA Y ESTRUCTURAS METÁLICAS** | 47.56d | 2008-03-26 | 2008-06-02 |  | 0.24d |  |  | 5798.72h | 253,340,990 | 04 | 04.01 | 4.1 |  |
| 44 | 5.1.1 | Platina de anclaje estructura metalica (incluye pintura) | 6.32d | 2008-03-26 | 2008-04-04 | 35 | 0.24d | 0d | OFICIAL [200%]; AYUDANTE [200%] | 202.08h | 4,952,030 | 04 | 04.01 | 4.1.1 | kg |
| 45 | 5.1.2 | Estructura metálica de cubierta (incluye pintura) | 20.41d | 2008-03-28 | 2008-04-25 | 44FS-8% | 0.24d | 0d | AYUDANTE [800%]; OFICIAL [800%] | 2612.96h | 67,938,000 | 04 | 04.01 | 4.1.2 | kg |
| 46 | 5.1.3 | Estructura metálica en ángulo para mampara de fachada descolgados y tapas cubiertas | 20.73d | 2008-04-11 | 2008-05-09 | 45FS-5% | 0.24d | 0d | AYUDANTE [200%]; OFICIAL [200%] | 663.52h | 15,091,600 | 04 | 04.01 | 4.1.3 | kg |
| 47 | 5.1.4 | Cubierta tipo sanduche deck C-MV (aluzinc) | 19.23d | 2008-04-25 | 2008-05-22 | 46FS-5%, 45 | 0.24d | 0d | OFICIAL [800%] | 1231.04h | 151,196,940 | 04 | 04.01 | 4.1.4 | m2 |
| 48 | 5.1.5 | Tapas laterales para cubierta en superboard 10 mm | 9.15d | 2008-05-09 | 2008-05-22 | 47FF | 0.24d | 0d | OFICIAL [300%]; AYUDANTE [600%] | 658.8h | 8,702,474 | 04 | 04.01 | 4.1.5 | m² |
| 49 | 5.1.6 | Remates cubierta en manto asfaltico e=2mm, L de desarrollo 0.30 m | 3.33d | 2008-05-22 | 2008-05-28 | 48 | 0.24d | 0d | OFICIAL; AYUDANTE [200%] | 79.92h | 926,100 | 04 | 04.01 | 4.1.6 |  |
| 50 | 5.1.7 | Canal en lamina galvanizada cal 24 L de desarrollo 1 metro | 3.05d | 2008-05-28 | 2008-06-02 | 49 | 0.24d | 0d | AYUDANTE [200%]; OFICIAL [200%] | 97.6h | 1,570,872 | 04 | 04.01 | 4.1.7 |  |
| 51 | 5.1.8 | Alfajia doble metalica L de desarrollo 0.30 m | 3.16d | 2008-05-28 | 2008-06-02 | 50SS | 0.24d | 0d | AYUDANTE [500%]; OFICIAL [500%] | 252.8h | 2,962,974 | 04 | 04.01 | 4.1.8 |  |
| 52 | 6 | **MAMPOSTERIA Y MUROS LIVIANOS** | 75.39d | 2008-02-04 | 2008-05-19 |  | 0.83d |  |  | 10210h | 193,748,686 | 05 | 05 |  |  |
| 53 | 6.1 | **MAMPOSTERIA Y MUROS LIVIANOS** | 75.39d | 2008-02-04 | 2008-05-19 |  | 0.83d |  |  | 10210h | 193,748,686 | 05 | 05.01 | 5.1 |  |
| 54 | 6.1.1 | Vigas y columnas de confinamiento para muros | 49.44d | 2008-02-08 | 2008-04-18 | 55FS-9% | 31.31d |  | AYUDANTE; OFICIAL | 791.04h | 15,747,660 | 05 | 05.01 | 5.1.1 |  |
| 55 | 6.1.2 | Muro en bloque estructural tipo split de 20x20x40 Indural | 46.73d | 2008-02-04 | 2008-04-08 | 35FS-5% | 5.34d | 0d | AYUDANTE [200%]; OFICIAL [200%] | 1495.36h | 32,032,920 | 05 | 05.01 | 5.1.2 | m2 |
| 56 | 6.1.3 | Muro en ladrillo farol | 55.04d | 2008-02-04 | 2008-04-21 | 35FS-5% | 0.83d | 0d | AYUDANTE; OFICIAL | 880.64h | 13,202,748 | 05 | 05.01 | 5.1.3 | m2 |
| 57 | 6.1.4 | Tapa en bloque estructural tipo split de Indural (20x40x5) para recubrimiento de exterior de las pantallas estructurales | 19.78d | 2008-03-26 | 2008-04-23 | 35 | 28.03d |  | AYUDANTE; OFICIAL | 316.48h | 8,779,850 | 05 | 05.01 | 5.1.4 | m2 |
| 58 | 6.1.5 | Tapas para mampara superboard 10 mm (fachada) | 24.28d | 2008-04-08 | 2008-05-13 | 55 | 5.34d | 0d | AYUDANTE [800%]; OFICIAL [400%] | 2331.12h | 31,445,190 | 05 | 05.01 | 5.1.5 | m2 |
| 59 | 6.1.6 | Fachada en superboard de 10mm dos caras para rampas | 28.69d | 2008-03-26 | 2008-05-06 | 35 | 6.75d | 0d | AYUDANTE [400%]; OFICIAL [200%] | 1377.12h | 34,620,534 | 05 | 05.01 | 5.1.6 | m2 |
| 60 | 6.1.7 | Muro interiores en superboard 8 mm | 44d | 2008-02-04 | 2008-04-04 | 55SS | 41.42d |  | AYUDANTE [40%]; OFICIAL [20%] | 211.2h | 4,378,440 | 05 | 05.01 | 5.1.7 | m2 |
| 61 | 6.1.8 | Cielo falso de panel yeso de 12.7 mm tipo Gyplac junta perdida | 20.35d | 2008-04-21 | 2008-05-19 | 56 | 3.52d | 0d | AYUDANTE [700%]; OFICIAL [700%] | 2279.04h | 43,652,880 | 05 | 05.01 | 5.1.8 | m2 |
| 62 | 6.1.9 | Tapa en muro reforzado con malla electrosoldada columnas acceso | 17.2d | 2008-03-03 | 2008-03-26 | 32 | 47.74d |  | AYUDANTE [200%]; OFICIAL | 412.8h | 6,992,144 | 05 | 05.01 | 5.1.9 | m2 |
| 63 | 6.1.10 | Tapas en superboard para bajantes | 4.8d | 2008-04-17 | 2008-04-24 | 147 | 27.07d |  | AYUDANTE [200%]; OFICIAL | 115.2h | 2,896,320 | 05 | 05.01 | 5.1.10 | ml |

| ID | WBS | Task | Duration | Start | Finish | Predecessors | Total slack | Free slack | Resources | Work | Cost | Text4 | Text5 | Text2 | Text1 |
| --- | --- | --- | --- | --- | --- | --- | --- | --- | --- | --- | --- | --- | --- | --- | --- |
| 64 | 7 | **REVOQUES** | 26.41d | 2008-03-12 | 2008-04-18 |  | 2.41d |  |  | 422.56h | 4,824,100 | 06 | 06 |  |  |
| 65 | 7.1 | **REVOQUES** | 26.41d | 2008-03-12 | 2008-04-18 |  | 2.41d |  |  | 422.56h | 4,824,100 | 06 | 06.01 | 6.1 |  |
| 66 | 7.1.1 | Revoques para muros en ladrillo farol | 26.41d | 2008-03-12 | 2008-04-18 | 56FS-5% | 2.41d | 0d | AYUDANTE; OFICIAL | 422.56h | 4,824,100 | 06 | 06.01 | 6.1.1 | m2 |
| 67 | 8 | **ACABADOS PARA MUROS INTERIORES Y EXTERIORES** | 49.11d | 2008-03-19 | 2008-05-28 |  | 3.52d |  |  | 2745.12h | 52,045,270 | 07 | 07 |  |  |
| 68 | 8.1 | **ACABADOS PARA MUROS INTERIORES Y EXTERIORES** | 49.11d | 2008-03-19 | 2008-05-28 |  | 3.52d |  |  | 2745.12h | 52,045,270 | 07 | 07.01 | 7.1 |  |
| 69 | 8.1.1 | Pintura cielo raso vinilo tipo 1, blanca 3 manos | 22.8d | 2008-04-25 | 2008-05-28 | 61FS-8% | 3.52d |  | AYUDANTE [300%]; OFICIAL [300%] | 1094.4h | 16,877,700 | 07 | 07.01 | 7.1.1 | m2 |
| 70 | 8.1.2 | Pintura texturada hidrorepelente tipo silicoplast para muros de fachada en ladrillo | 12.37d | 2008-05-06 | 2008-05-22 | 59 | 6.75d |  | AYUDANTE [300%]; OFICIAL [300%] | 593.6h | 14,059,794 | 07 | 07.01 | 7.1.2 | m² |
| 71 | 8.1.3 | Pintura tipo 1 Blanca 3 manos se aplicara en los muros interiores | 44.05d | 2008-03-19 | 2008-05-21 | 66FS-8% | 8.58d |  | AYUDANTE [150%]; OFICIAL [150%] | 1057.12h | 21,107,776 | 07 | 07.01 | 7.1.3 | m2 |
| 72 | 9 | **PISOS Y ENCHAPES** | 57.08d | 2008-03-12 | 2008-05-30 |  | 0.83d |  |  | 9246.72h | 250,083,613 | 08 | 08 |  |  |
| 73 | 9.1 | **PISOS Y ENCHAPES** | 57.08d | 2008-03-12 | 2008-05-30 |  | 0.83d |  |  | 9246.72h | 250,083,613 | 08 | 08.01 | 8.1 |  |
| 74 | 9.1.1 | Enchape en cerámica 30cmsx30cms blanca rectificada | 13.16d | 2008-04-18 | 2008-05-07 | 66 | 2.41d | 0d | AYUDANTE [400%]; OFICIAL [400%] | 842.08h | 21,841,901 | 08 | 08.01 | 8.1.1 | m2 |
| 75 | 9.1.2 | Huella y contrahuella en granito escalas | 12.53d | 2008-04-30 | 2008-05-16 | 83 | 10.8d |  | AYUDANTE [300%]; OFICIAL [300%] | 601.6h | 17,676,512 | 08 | 08.01 | 8.1.2 | m2 |
| 76 | 9.1.3 | Guardaescoba en madera algarrobo altura= 0,07 mts | 7.63d | 2008-05-19 | 2008-05-29 | 78 | 2.43d |  | AYUDANTE; OFICIAL | 122.08h | 2,750,061 | 08 | 08.01 | 8.1.3 |  |
| 77 | 9.1.4 | Guardaescoba En Baldosa Tipo Roca base blanca grano L=30 Cms | 15.89d | 2008-05-08 | 2008-05-29 | 78FS-2% | 1.67d | 1.42d | AYUDANTE [600%]; OFICIAL [600%] | 1525.6h | 23,342,865 | 08 | 08.01 | 8.1.4 |  |
| 78 | 9.1.5 | Piso en baldosa tipo terrazo de 30x30 grano No 3 capa de desgaste 4,5 mm. | 37.47d | 2008-03-27 | 2008-05-19 | 83FS-7% | 0.91d | 0d | AYUDANTE [700%]; OFICIAL [700%] | 4196.8h | 128,411,588 | 08 | 08.01 | 8.1.5 | m2 |
| 79 | 9.1.6 | Piso en baldosa tipo terrazo de 30x30 antideslizantede grano No 3 | 9.15d | 2008-05-19 | 2008-05-30 | 78 | 0.91d |  | AYUDANTE [200%]; OFICIAL [200%] | 292.8h | 9,169,398 | 08 | 08.01 | 8.1.6 | m2 |
| 80 | 9.1.7 | Piso en Vinisol | 16.92d | 2008-05-06 | 2008-05-28 | 83FS-3%, 81FS-3% | 0.83d | 0d | AYUDANTE; OFICIAL | 270.72h | 14,709,120 | 08 | 08.01 | 8.1.7 | m2 |
| 81 | 9.1.8 | Placa en superboard de 17 mm para piso de aulas tipo 2. No incluye estructura | 39.98d | 2008-03-27 | 2008-05-22 | 83FS-7% | 0.83d | 0d | AYUDANTE; OFICIAL | 639.68h | 22,251,600 | 08 | 08.01 | 8.1.8 | m2 |
| 82 | 9.1.9 | Poceta de aseo en grano pulido en cuartos de aseo | 1.8d | 2008-05-28 | 2008-05-30 | 80 | 0.83d | 0.58d | AYUDANTE; OFICIAL | 28.8h | 319,768 | 08 | 08.01 | 8.1.9 | un |
| 83 | 9.1.10 | Mortero de nivelacion 1:3 | 34.57d | 2008-03-12 | 2008-04-30 | 56FS-5% | 0.83d | 0d | AYUDANTE; OFICIAL | 553.12h | 5,360,970 | 08 | 08.01 | 8.1.10 | m2 |
| 84 | 9.1.11 | Piso en concreto endurecido para area de servicios generales | 10.84d | 2008-04-30 | 2008-05-15 | 83 | 12.49d |  | AYUDANTE; OFICIAL | 173.44h | 4,249,830 | 08 | 08.01 | 8.1.11 | m2 |
| 85 | 10 | **APARATOS SANITARIOS** | 12.38d | 2008-05-06 | 2008-05-23 |  | 6.55d |  |  | 715.6h | 146,663,695 | 09 | 09 |  |  |
| 86 | 10.1 | **APARATOS SANITARIOS** | 12.38d | 2008-05-06 | 2008-05-23 |  | 6.55d |  |  | 715.6h | 146,663,695 | 09 | 09.01 | 9.1 |  |
| 87 | 10.1.1 | Sanitario mancesa con fluxometro | 7d | 2008-05-06 | 2008-05-15 | 113FS-5%, 181FS-5% | 6.55d | 0d | OFICIAL [300%] | 168h | 44,131,206 | 09 | 09.01 | 9.1.1 | un |
| 88 | 10.1.2 | Orinal griferia de sensor | 6.67d | 2008-05-06 | 2008-05-15 | 87SS | 6.55d | 0d | OFICIAL [300%] | 160h | 40,342,200 | 09 | 09.01 | 9.1.2 | un |
| 89 | 10.1.3 | Lavamanos blanco tipo lavatus o similar griferia de sensor | 1d | 2008-05-15 | 2008-05-16 | 88 | 11.26d |  | OFICIAL | 8h | 1,331,110 | 09 | 09.01 | 9.1.3 | un |
| 90 | 10.1.4 | Lavamanos de empotrar blanco tipo lavatus LC 4171 PLTR redondo o similar, griferia de sensor | 7.33d | 2008-05-06 | 2008-05-15 | 88SS | 6.55d | 0d | OFICIAL [300%] | 176h | 29,473,620 | 09 | 09.01 | 9.1.4 | un |
| 91 | 10.1.5 | Espejo 3,10 x 0,80 m calidad peldar bordes biselados | 1d | 2008-05-15 | 2008-05-16 | 90 | 6.55d | 0d | OFICIAL | 8h | 528,960 | 09 | 09.01 | 9.1.5 | un |
| 92 | 10.1.6 | Barras de apoyo en acero inoxidable | 4.05d | 2008-05-16 | 2008-05-23 | 91 | 6.55d | 6.3d | OFICIAL | 32.4h | 1,306,638 | 09 | 09.01 | 9.1.6 | un |
| 93 | 10.1.7 | Mesón y salpicadero en granito pulido negro absoluto con babero y charquero vaciados in situ sobre pie de amigo metalico | 6.8d | 2008-05-06 | 2008-05-15 | 90SS | 12.13d |  | OFICIAL [300%] | 163.2h | 29,549,961 | 09 | 09.01 | 9.1.7 |  |

| ID | WBS | Task | Duration | Start | Finish | Predecessors | Total slack | Free slack | Resources | Work | Cost | Text2 | Text4 | Text5 | Text1 |
| --- | --- | --- | --- | --- | --- | --- | --- | --- | --- | --- | --- | --- | --- | --- | --- |
| 94 | 11 | **CARPINTERIA METALICA** | 46.85d | 2008-03-25 | 2008-05-29 |  | 2.41d |  |  | 8541.92h | 205,384,866 | 10 | 10 | 10 |  |
| 95 | 11.1 | **CARPINTERIA METALICA** | 46.85d | 2008-03-25 | 2008-05-29 |  | 2.41d |  |  | 8541.92h | 205,384,866 | 10.1 | 10 | 10.01 |  |
| 96 | 11.1.1 | Estructura en esqueleto metálico escalonada no estructural para soporte piso en superboard en aulas | 40.04d | 2008-03-25 | 2008-05-20 | 83FS-7.5% | 9.22d |  | AYUDANTE [540%]; OFICIAL [540%] | 3459.52h | 78,684,480 | 10.1.1 | 10 | 10.01 | kg |
| 97 | 11.1.2 | Pasamanos en tuberia aguas negras 2" pintada en color aluminio | 5.83d | 2008-05-13 | 2008-05-20 | 58 | 5.34d | 0d | AYUDANTE; OFICIAL | 93.28h | 1,829,030 | 10.1.2 | 10 | 10.01 |  |
| 98 | 11.1.3 | Pasamanos en tubo aguas negras de 2" con anticorrosivo y acabado en pintura de esmalte color aluminio | 9.07d | 2008-05-13 | 2008-05-26 | 97SS | 5.34d |  | AYUDANTE [500%]; OFICIAL [500%] | 725.44h | 14,214,176 | 10.1.3 | 10 | 10.01 |  |
| 99 | 11.1.4 | Puerta tipo p-1 lamina entamb. | 24.7d | 2008-03-31 | 2008-05-05 | 66FS-5% | 17.7d | 0d | AYUDANTE; OFICIAL [50%] | 296.4h | 5,263,944 | 10.1.4 | 10 | 10.01 | un |
| 100 | 11.1.5 | Puerta tipo p-4 lamina entamb. Vidrio templado tipo banco, con celosia en aluminio, chapa antipanico y reja lateral | 24d | 2008-03-31 | 2008-05-02 | 99SS | 17.7d | 0d | AYUDANTE [25%]; OFICIAL [25%] | 96h | 4,672,894 | 10.1.5 | 10 | 10.01 | un |
| 101 | 11.1.6 | Puerta tipo p-5 lamina entamb.parte inferior y el resto en reja metalica | 25d | 2008-03-31 | 2008-05-05 | 100SS | 17.7d | 0d | AYUDANTE [200%]; OFICIAL [200%] | 800h | 11,595,200 | 10.1.6 | 10 | 10.01 | un |
| 102 | 11.1.7 | Puerta tipo p-6 lamina mirilla marcada con adhesivo opalizado | 23.53d | 2008-03-31 | 2008-05-02 | 101SS | 17.7d | 0d | AYUDANTE [170%]; OFICIAL [170%] | 640h | 7,586,600 | 10.1.7 | 10 | 10.01 | un |
| 103 | 11.1.8 | Puerta tipo p-7 lamina | 24.38d | 2008-03-31 | 2008-05-05 | 102SS | 17.7d | 0d | OFICIAL [32%]; AYUDANTE [65%] | 187.2h | 4,144,985 | 10.1.8 | 10 | 10.01 | un |
| 104 | 11.1.9 | Puerta tipo p-7A a= 0.5m para ductos | 24.35d | 2008-03-31 | 2008-05-05 | 103SS | 17.7d | 0d | AYUDANTE [47%]; OFICIAL [23%] | 134.4h | 3,320,676 | 10.1.9 | 10 | 10.01 | un |
| 105 | 11.1.10 | Puerta tipo p-8 lamina entamborada | 24d | 2008-03-31 | 2008-05-02 | 104SS | 17.7d | 0d | AYUDANTE [25%]; OFICIAL [25%] | 96h | 3,206,000 | 10.1.10 | 10 | 10.01 | un |
| 106 | 11.1.11 | Puerta tipo p-9 lamina entamb. Incluye chapa de seguridad ref 947 con falleva super/inferior | 25d | 2008-03-31 | 2008-05-05 | 105SS | 17.7d | 0d | AYUDANTE [4%]; OFICIAL [4%] | 16h | 1,003,418 | 10.1.11 | 10 | 10.01 | un |
| 107 | 11.1.12 | Puerta tipo p-10 lamina entamb. | 25d | 2008-03-31 | 2008-05-05 | 106SS | 17.7d | 0d | OFICIAL [8%]; AYUDANTE [8%] | 30.4h | 1,029,692 | 10.1.12 | 10 | 10.01 | un |
| 108 | 11.1.13 | Puerta tipo p-11 puerta ventana | 24.07d | 2008-03-31 | 2008-05-02 | 107SS | 17.7d | 0d | AYUDANTE [81%]; OFICIAL [81%] | 312h | 6,932,160 | 10.1.13 | 10 | 10.01 | un |
| 109 | 11.1.14 | Puerta tipo P-12 | 25d | 2008-03-31 | 2008-05-05 | 108SS | 17.7d | 0d | AYUDANTE [4%]; OFICIAL [4%] | 16h | 274,652 | 10.1.14 | 10 | 10.01 | un |
| 110 | 11.1.15 | Dilatación perfil en aluminio natural en U 1cmx1cm instalación cóncava | 15.93d | 2008-05-07 | 2008-05-29 | 74 | 2.41d | 2.17d | OFICIAL [120%] | 152.88h | 2,770,124 | 10.1.15 | 10 | 10.01 |  |
| 111 | 11.1.16 | Escalera de gato observatorio tuberia galvanizada tipo pesado y pasos de 1" cada 40 cm | 0.7d | 2008-05-22 | 2008-05-23 | 47 | 5.83d | 0d | OFICIAL; AYUDANTE | 11.2h | 367,500 | 10.1.16 | 10 | 10.01 |  |
| 112 | 11.1.17 | Escotilla en lamina alfajor para acceso a terraza observatorio de 0,65 x 0,8m | 0.2d | 2008-05-23 | 2008-05-23 | 111 | 5.83d |  | AYUDANTE; OFICIAL | 3.2h | 99,479 | 10.1.17 | 10 | 10.01 | un |
| 113 | 11.1.18 | Divisiones de baño en acero inoxidable | 22.5d | 2008-04-21 | 2008-05-21 | 74FS-9% | 6.55d | 0d | AYUDANTE [400%]; OFICIAL [400%] | 1440h | 57,760,560 | 10.1.18 | 10 | 10.01 | m2 |
| 114 | 11.1.19 | Puerta P-7 v 1x2.20 | 2d | 2008-05-05 | 2008-05-07 | 109 | 17.7d |  | AYUDANTE; OFICIAL | 32h | 629,296 | 10.1.19 | 10 | 10.01 | un |
| 115 | 12 | **CARPINTERIA EN ALUMINIO** | 26.32d | 2008-04-18 | 2008-05-26 |  | 5.17d |  |  | 3052.56h | 113,346,788 | 11 | 11 | 11 |  |
| 116 | 12.1 | **CARPINTERIA EN ALUMINIO** | 26.32d | 2008-04-18 | 2008-05-26 |  | 5.17d |  |  | 3052.56h | 113,346,788 | 11.1 | 11 | 11.01 |  |
| 117 | 12.1.1 | Ventana tipo v-1 salones | 24d | 2008-04-18 | 2008-05-22 | 66 | 5.17d | 0d | AYUDANTE [233%]; OFICIAL [233%] | 894.72h | 23,379,312 | 11.1.1 | 11 | 11.01 | un |
| 118 | 12.1.2 | Ventana tipo v-1´ salones | 24.05d | 2008-04-18 | 2008-05-22 | 117SS | 5.17d | 0d | AYUDANTE [127%]; OFICIAL [127%] | 488.64h | 12,781,650 | 11.1.2 | 11 | 11.01 | un |
| 119 | 12.1.3 | Ventana tipo v-2 baños | 24.15d | 2008-04-18 | 2008-05-22 | 118SS | 5.17d | 0d | AYUDANTE [27%]; OFICIAL [27%] | 104.32h | 2,726,592 | 11.1.3 | 11 | 11.01 | un |
| 120 | 12.1.4 | Ventana tipo v-2' baños | 23.67d | 2008-04-18 | 2008-05-21 | 119SS | 5.17d | 0d | AYUDANTE [9%]; OFICIAL [9%] | 34.08h | 882,305 | 11.1.4 | 11 | 11.01 | un |
| 121 | 12.1.5 | Ventana tipo v-5 observatorio | 0.8d | 2008-05-21 | 2008-05-22 | 120 | 6.28d | 0d | AYUDANTE; OFICIAL | 12.8h | 334,395 | 11.1.5 | 11 | 11.01 | un |
| 122 | 12.1.6 | Ventana tipo v-5' acceso observatorio | 0.75d | 2008-05-22 | 2008-05-23 | 121 | 6.28d |  | AYUDANTE; OFICIAL | 12h | 312,405 | 11.1.6 | 11 | 11.01 | un |
| 123 | 12.1.7 | Ventana tipo v-8 fachada flotante | 23.94d | 2008-04-18 | 2008-05-22 | 120SS | 5.17d | 0d | AYUDANTE [65%]; OFICIAL [65%] | 248.96h | 6,509,876 | 11.1.7 | 11 | 11.01 | m2 |
| 124 | 12.1.8 | Ventana tipo v-11 administracion | 0.97d | 2008-05-22 | 2008-05-22 | 123 | 6.59d |  | AYUDANTE; OFICIAL | 15.52h | 404,997 | 11.1.8 | 11 | 11.01 | un |
| 125 | 12.1.9 | Ventana tipo v-12 servicios generales | 24.4d | 2008-04-18 | 2008-05-22 | 123SS | 5.17d | 0d | AYUDANTE [10%]; OFICIAL [10%] | 39.04h | 1,022,418 | 11.1.9 | 11 | 11.01 | un |
| 126 | 12.1.10 | Ventana tipo v-13 servicios generales | 0.32d | 2008-05-22 | 2008-05-22 | 125 | 6.78d |  | AYUDANTE; OFICIAL | 5.12h | 150,004 | 11.1.10 | 11 | 11.01 | un |
| 127 | 12.1.11 | Ventana tipo v-14 servicios generales | 22.81d | 2008-04-18 | 2008-05-20 | 125SS | 5.17d | 0d | AYUDANTE [150%]; OFICIAL [150%] | 547.52h | 14,313,621 | 11.1.11 | 11 | 11.01 | un |
| 128 | 12.1.12 | Ventana tipo v-15 mampara superior aulas | 20.37d | 2008-04-18 | 2008-05-16 | 127SS | 5.17d | 0d | AYUDANTE; OFICIAL | 325.92h | 8,520,030 | 11.1.12 | 11 | 11.01 | un |
| 129 | 12.1.13 | Cortasol aerobrise 200 aluzinc 0.5mm horizontal | 8.21d | 2008-05-02 | 2008-05-14 | 128FS-5% | 5.17d | 0d | OFICIAL [300%] | 197.04h | 38,692,510 | 11.1.13 | 11 | 11.01 | m2 |
| 130 | 12.1.14 | Ventana V-1A | 5.09d | 2008-05-14 | 2008-05-21 | 129 | 5.17d | 0d | AYUDANTE; OFICIAL | 81.44h | 2,130,275 | 11.1.14 | 11 | 11.01 | un |
| 131 | 12.1.15 | Ventana V-17 | 2.04d | 2008-05-21 | 2008-05-23 | 130 | 5.17d | 0d | AYUDANTE; OFICIAL | 32.64h | 852,003 | 11.1.15 | 11 | 11.01 | un |
| 132 | 12.1.16 | Reja Ventana 1.05x0.85 m Varilla cuadrada d=1/2" | 0.8d | 2008-05-23 | 2008-05-26 | 131 | 5.17d |  | AYUDANTE; OFICIAL | 12.8h | 334,395 | 11.1.16 | 11 | 11.01 | un |

| ID | WBS | Task | Duration | Start | Finish | Predecessors | Total slack | Free slack | Resources | Work | Cost | Text2 | Text4 | Text5 | Text1 |
| --- | --- | --- | --- | --- | --- | --- | --- | --- | --- | --- | --- | --- | --- | --- | --- |
| 133 | 13 | **RED DE INCENDIO** | 32.4d | 2008-03-20 | 2008-05-05 |  | 15.58d |  |  | 273.25h | 22,338,237 | 12 | 12 | 12 |  |
| 134 | 13.1 | **RED DE INCENDIO** | 32.4d | 2008-03-20 | 2008-05-05 |  | 15.58d |  |  | 273.25h | 22,338,237 | 12.1 | 12 | 12.01 |  |
| 135 | 13.1.1 | Tuberia pvc presion rde -21 incluye accesorios d= 3" | 13.9d | 2008-03-20 | 2008-04-09 | 56FS-4% | 15.58d | 0d | OFICIAL [10%]; AYUDANTE [20%] | 33.25h | 2,809,550 | 12.1.1 | 12 | 12.01 | ml |
| 136 | 13.1.2 | Tuberia hg d= 3" | 3d | 2008-04-09 | 2008-04-14 | 135 | 20d | 0d | AYUDANTE [200%]; OFICIAL | 72h | 2,077,560 | 12.1.2 | 12 | 12.01 | ml |
| 137 | 13.1.3 | Siamesa 3 x 2 1/2 x 2 1/2" | 1d | 2008-04-14 | 2008-04-15 | 136 | 20d | 0d | AYUDANTE; OFICIAL | 16h | 1,080,115 | 12.1.3 | 12 | 12.01 | un |
| 138 | 13.1.4 | Gabinete de incendio de 0,77 x 0,77 x 0,22 , manguera de 100 pies | 4.5d | 2008-04-15 | 2008-04-21 | 137 | 20d | 0d | AYUDANTE; OFICIAL | 72h | 9,153,522 | 12.1.4 | 12 | 12.01 | un |
| 139 | 13.1.5 | SUMINISTRO E INSTALACION EQUIPO HIDRONEUMATICO RED DE INCENDIO | 10d | 2008-04-21 | 2008-05-05 | 138 | 20d | 19.76d | OFICIAL | 80h | 7,217,490 | 12.1.5 | 12 | 12.01 | un |
| 140 | 14 | **INSTALACION SANITARIA PVC** | 80d | 2008-01-02 | 2008-04-23 |  | 27.07d |  |  | 3968.32h | 78,494,955 | 13 | 13 | 13 |  |
| 141 | 14.1 | **INSTALACION SANITARIA PVC** | 80d | 2008-01-02 | 2008-04-23 |  | 27.07d |  |  | 3968.32h | 78,494,955 | 13.1 | 13 | 13.01 |  |
| 142 | 14.1.1 | D= 2" | 78.36d | 2008-01-02 | 2008-04-21 | 35FS-8% | 27.07d | 0d | AYUDANTE [23%]; OFICIAL [11%] | 206.88h | 4,630,664 | 13.1.1 | 13 | 13.01 | ml |
| 143 | 14.1.2 | D=3" | 77d | 2008-01-02 | 2008-04-18 | 142SS | 27.07d | 0d | AYUDANTE [4%]; OFICIAL [2%] | 36.96h | 1,097,712 | 13.1.2 | 13 | 13.01 | ml |
| 144 | 14.1.3 | D= 4" | 74.73d | 2008-01-02 | 2008-04-16 | 143SS | 27.07d | 0d | AYUDANTE [22%]; OFICIAL [11%] | 197.28h | 7,351,968 | 13.1.3 | 13 | 13.01 | ml |
| 145 | 14.1.4 | D= 2" | 75d | 2008-01-02 | 2008-04-16 | 144SS | 27.07d | 0d | AYUDANTE [36%]; OFICIAL [36%] | 432h | 5,470,065 | 13.1.4 | 13 | 13.01 | un |
| 146 | 14.1.5 | D=3" | 80d | 2008-01-02 | 2008-04-23 | 145SS | 27.07d | 0d | AYUDANTE [3%]; OFICIAL [3%] | 38.4h | 592,596 | 13.1.5 | 13 | 13.01 | un |
| 147 | 14.1.6 | D= 4" | 76.13d | 2008-01-02 | 2008-04-17 | 146SS | 27.07d | 0d | AYUDANTE [31%]; OFICIAL [31%] | 377.6h | 7,857,266 | 13.1.6 | 13 | 13.01 | un |
| 148 | 14.1.7 | D= 160 mm | 75.25d | 2008-01-02 | 2008-04-16 | 147SS | 28d | 0d | AYUDANTE [51%]; OFICIAL [51%] | 614.08h | 10,242,134 | 13.1.7 | 13 | 13.01 | ml |
| 149 | 14.1.8 | D= 200 mm | 76.25d | 2008-01-02 | 2008-04-17 | 148SS | 28d | 0d | AYUDANTE [40%]; OFICIAL [40%] | 488h | 10,054,996 | 13.1.8 | 13 | 13.01 | ml |
| 150 | 14.1.9 | D= 315 mm | 73.63d | 2008-01-02 | 2008-04-15 | 149SS | 28d | 0d | AYUDANTE [27%]; OFICIAL [27%] | 318.08h | 8,451,804 | 13.1.9 | 13 | 13.01 | ml |
| 151 | 14.1.10 | D= 2" | 52d | 2008-01-02 | 2008-03-14 | 150SS | 28d | 0d | AYUDANTE [2%]; OFICIAL [1%] | 12.48h | 236,301 | 13.1.10 | 13 | 13.01 | ml |
| 152 | 14.1.11 | 0,60 * 0,60 | 70d | 2008-01-02 | 2008-04-09 | 151SS | 28d | 0d | AYUDANTE [3%]; OFICIAL [3%] | 33.6h | 411,603 | 13.1.11 | 13 | 13.01 | un |
| 153 | 14.1.12 | 0,80 * 0,80 | 76.9d | 2008-01-02 | 2008-04-18 | 152SS | 28d | 0d | AYUDANTE [21%]; OFICIAL [21%] | 258.4h | 3,837,905 | 13.1.12 | 13 | 13.01 | un |
| 154 | 14.1.13 | 1,00* 1,00 | 45d | 2008-01-02 | 2008-03-05 | 153SS | 28d | 0d | AYUDANTE [2%]; OFICIAL [2%] | 14.4h | 283,185 | 13.1.13 | 13 | 13.01 | un |
| 155 | 14.1.14 | 1,60*0,70*0,90 | 80d | 2008-01-02 | 2008-04-23 | 154SS | 28d | 0d | AYUDANTE [1%]; OFICIAL [1%] | 12.8h | 2,301,860 | 13.1.14 | 13 | 13.01 | un |
| 156 | 14.1.15 | Base y cañuela | 66.67d | 2008-01-02 | 2008-04-04 | 155SS | 29.28d | 0d | AYUDANTE [3%]; OFICIAL [3%] | 32h | 946,376 | 13.1.15 | 13 | 13.01 | un |
| 157 | 14.1.16 | Cuerpo | 76.67d | 2008-01-02 | 2008-04-18 | 156SS | 29.28d | 0d | AYUDANTE [36%]; OFICIAL [36%] | 441.6h | 4,580,542 | 13.1.16 | 13 | 13.01 | ml |
| 158 | 14.1.17 | Tapa | 75.15d | 2008-01-02 | 2008-04-16 | 157SS | 29.28d | 0d | AYUDANTE [33%]; OFICIAL [33%] | 396.8h | 9,136,878 | 13.1.17 | 13 | 13.01 | un |
| 159 | 14.1.18 | Peldaños | 2.16d | 2008-04-16 | 2008-04-18 | 158 | 29.28d | 0d | AYUDANTE; OFICIAL | 34.56h | 503,880 | 13.1.18 | 13 | 13.01 | un |
| 160 | 14.1.19 | CABEZOTE DE DESCOLE | 1.4d | 2008-04-18 | 2008-04-22 | 159 | 29.28d |  | AYUDANTE; OFICIAL | 22.4h | 507,220 | 13.1.19 | 13 | 13.01 | un |

| ID | WBS | Task | Duration | Start | Finish | Predecessors | Total slack | Free slack | Resources | Work | Cost | Text2 | Text4 | Text5 | Text1 |
| --- | --- | --- | --- | --- | --- | --- | --- | --- | --- | --- | --- | --- | --- | --- | --- |
| 161 | 15 | **INSTALACION HIDRAULICA PVC** | 20.98d | 2008-04-09 | 2008-05-08 |  | 15.58d |  |  | 603.34h | 22,071,542 | 14 | 14 | 14 |  |
| 162 | 15.1 | **INSTALACION HIDRAULICA PVC** | 20.98d | 2008-04-09 | 2008-05-08 |  | 15.58d |  |  | 603.34h | 22,071,542 | 14.1 | 14 | 14.01 |  |
| 163 | 15.1.1 | D= 1/2" | 2.35d | 2008-04-09 | 2008-04-11 | 135 | 15.58d | 0d | AYUDANTE [200%]; OFICIAL | 56.4h | 770,408 | 14.1.1 | 14 | 14.01 | ml |
| 164 | 15.1.2 | D= 3/4" | 0.71d | 2008-04-11 | 2008-04-14 | 163 | 28.64d | 0d | AYUDANTE [201%]; OFICIAL | 17.04h | 280,269 | 14.1.2 | 14 | 14.01 | ml |
| 165 | 15.1.3 | D= 1" | 1.49d | 2008-04-14 | 2008-04-15 | 164 | 28.64d | 0d | AYUDANTE [201%]; OFICIAL | 35.76h | 707,728 | 14.1.3 | 14 | 14.01 | ml |
| 166 | 15.1.4 | D= 1 1/4" | 0.48d | 2008-04-15 | 2008-04-16 | 165 | 28.64d | 0d | AYUDANTE [200%]; OFICIAL | 11.52h | 236,196 | 14.1.4 | 14 | 14.01 | ml |
| 167 | 15.1.5 | D= 1 1/2" | 0.06d | 2008-04-16 | 2008-04-16 | 166 | 28.64d | 0d | OFICIAL; AYUDANTE [183%] | 1.36h | 34,352 | 14.1.5 | 14 | 14.01 | ml |
| 168 | 15.1.6 | D= 2" | 0.54d | 2008-04-16 | 2008-04-16 | 167 | 28.64d | 0d | AYUDANTE [200%]; OFICIAL | 12.96h | 423,430 | 14.1.6 | 14 | 14.01 | ml |
| 169 | 15.1.7 | D= 2 1/2" | 1.39d | 2008-04-16 | 2008-04-18 | 168 | 28.64d | 0d | OFICIAL; AYUDANTE [199%] | 33.25h | 1,494,090 | 14.1.7 | 14 | 14.01 | ml |
| 170 | 15.1.8 | D= 3" | 0.38d | 2008-04-18 | 2008-04-18 | 169 | 28.64d | 0d | OFICIAL; AYUDANTE [203%] | 9.21h | 765,946 | 14.1.8 | 14 | 14.01 | ml |
| 171 | 15.1.9 | D= 1/2" | 0.46d | 2008-04-18 | 2008-04-18 | 170 | 28.64d | 0d | AYUDANTE; OFICIAL | 7.36h | 293,909 | 14.1.9 | 14 | 14.01 | un |
| 172 | 15.1.10 | D= 1" | 0.5d | 2008-04-18 | 2008-04-21 | 171 | 28.64d | 0d | AYUDANTE; OFICIAL | 8h | 514,420 | 14.1.10 | 14 | 14.01 | un |
| 173 | 15.1.11 | D= 1 1/2" | 0.47d | 2008-04-21 | 2008-04-21 | 172 | 28.64d | 0d | AYUDANTE; OFICIAL | 7.52h | 609,008 | 14.1.11 | 14 | 14.01 | un |
| 174 | 15.1.12 | D= 2 " | 0.13d | 2008-04-21 | 2008-04-22 | 173 | 28.64d | 0d | AYUDANTE; OFICIAL | 2.08h | 237,874 | 14.1.12 | 14 | 14.01 | un |
| 175 | 15.1.13 | D= 2 1/2" | 0.2d | 2008-04-22 | 2008-04-22 | 174 | 28.64d | 0d | AYUDANTE; OFICIAL | 3.2h | 444,880 | 14.1.13 | 14 | 14.01 | un |
| 176 | 15.1.14 | D= 3" | 0.5d | 2008-04-22 | 2008-04-22 | 175 | 28.64d | 0d | AYUDANTE; OFICIAL | 8h | 1,560,860 | 14.1.14 | 14 | 14.01 | un |
| 177 | 15.1.15 | Llave ducha individual grival | 0.2d | 2008-04-22 | 2008-04-22 | 176 | 28.64d |  | OFICIAL | 1.6h | 51,514 | 14.1.15 | 14 | 14.01 | un |
| 178 | 15.1.16 | Punto HG d= 1/2" | 2.25d | 2008-04-11 | 2008-04-15 | 163 | 15.58d | 0d | OFICIAL | 18h | 331,875 | 14.1.16 | 14 | 14.01 | un |
| 179 | 15.1.17 | Puntos hidraulicos 1/2 | 9.5d | 2008-04-11 | 2008-04-24 | 178SS | 15.58d | 0d | AYUDANTE; OFICIAL | 152h | 1,795,576 | 14.1.17 | 14 | 14.01 | un |
| 180 | 15.1.18 | Puntos hidraulicos 1 1/4 | 8d | 2008-04-11 | 2008-04-23 | 179SS | 15.58d | 0d | AYUDANTE; OFICIAL | 128h | 2,131,456 | 14.1.18 | 14 | 14.01 | un |
| 181 | 15.1.19 | Puntos hidraulicos 2 | 0.38d | 2008-04-23 | 2008-04-23 | 180 | 15.58d | 0d | AYUDANTE; OFICIAL | 6.08h | 194,070 | 14.1.19 | 14 | 14.01 | un |
| 182 | 15.1.20 | Válvula cheque vertical d= 3" | 0.1d | 2008-04-23 | 2008-04-23 | 181 | 17.52d | 0d | AYUDANTE; OFICIAL | 1.6h | 670,832 | 14.1.20 | 14 | 14.01 | un |
| 183 | 15.1.21 | Válvula cheque horizontal d= 2 1/2" | 0.05d | 2008-04-23 | 2008-04-23 | 182 | 17.52d | 0d | AYUDANTE; OFICIAL | 0.8h | 286,541 | 14.1.21 | 14 | 14.01 | un |
| 184 | 15.1.22 | Válvula cheque horizontal d= 3" | 0.05d | 2008-04-23 | 2008-04-24 | 183 | 17.52d | 0d | AYUDANTE; OFICIAL | 0.8h | 398,041 | 14.1.22 | 14 | 14.01 | un |
| 185 | 15.1.23 | Válvula flotador d= 1" | 0.05d | 2008-04-24 | 2008-04-24 | 184 | 17.52d | 0d | AYUDANTE; OFICIAL | 0.8h | 78,267 | 14.1.23 | 14 | 14.01 | un |
| 186 | 15.1.24 | Equipo de presion | 10d | 2008-04-24 | 2008-05-08 | 185 | 17.52d | 17.28d | OFICIAL | 80h | 7,760,000 | 14.1.24 | 14 | 14.01 | un |

| ID | WBS | Task | Type | Duration | Start | Finish | Predecessors | Total slack | Free slack | Resources | Work | Cost | Text2 | Text4 | Text5 | Text1 |
| --- | --- | --- | --- | --- | --- | --- | --- | --- | --- | --- | --- | --- | --- | --- | --- | --- |
| 187 | 16 | **REDES ELECTRICAS** |  | 102.17d | 2007-11-19 | 2008-04-09 |  | 37.74d |  |  | 961.36h | 22,983,168 | 15 | 16 | 16 |  |
| 188 | 16.1 | **REDES ELECTRICAS** |  | 102.17d | 2007-11-19 | 2008-04-09 |  | 37.74d |  |  | 961.36h | 22,983,168 | 15.1 | 16 | 16.01 |  |
| 189 | 16.1.1 | Malla tierra subestación 2/0, 2,4 mts, cadweld,sanikgel |  | 30d | 2007-11-19 | 2007-12-31 | 16 | 37.74d | 0d | OFICIAL | 240h | 4,917,800 | 15.1.1 | 16 | 16.01 | un |
| 190 | 16.1.2 | Malla a tierra pararayos 1/0 2.4 metros cadweld, sanik gel |  | 30d | 2007-12-31 | 2008-02-11 | 189 | 37.74d | 0d | OFICIAL | 240h | 4,917,800 | 15.1.2 | 16 | 16.01 | un |
| 191 | 16.1.3 | Foso protección transformador |  | 6d | 2008-02-11 | 2008-02-19 | 190 | 37.74d | 0d | AYUDANTE [300%]; OFICIAL | 192h | 2,160,599 | 15.1.3 | 16 | 16.01 | gl |
| 192 | 16.1.4 | Acometida transformador - subestación |  | 3.33d | 2008-02-19 | 2008-02-22 | 191 | 37.74d | 0d | OFICIAL | 26.64h | 6,570,580 | 15.1.4 | 16 | 16.01 | ml |
| 193 | 16.1.5 | Acometida t. Bombas incendio |  | 10.84d | 2008-02-22 | 2008-03-10 | 192 | 37.74d | 0d | OFICIAL | 86.72h | 1,318,005 | 15.1.5 | 16 | 16.01 | ml |
| 194 | 16.1.6 | Acometida t. Bombas consumo |  | 5d | 2008-03-10 | 2008-03-17 | 193 | 37.74d | 0d | OFICIAL | 40h | 608,310 | 15.1.6 | 16 | 16.01 | ml |
| 195 | 16.1.7 | Interconexion electrica modulos 5x3" |  | 11.17d | 2008-03-17 | 2008-04-02 | 194 | 37.74d | 0d | OFICIAL | 89.36h | 1,358,559 | 15.1.7 | 16 | 16.01 | ml |
| 196 | 16.1.8 | Interconexion UTP 3X4 |  | 5.83d | 2008-04-02 | 2008-04-09 | 195 | 37.74d | 37.5d | OFICIAL | 46.64h | 1,131,515 | 15.1.8 | 16 | 16.01 | ml |
| 197 | 17 | **BOVEDA ARQUEOLÓGICA** |  | 76.37d | 2008-01-02 | 2008-04-17 |  | 30.24d |  |  | 1130.48h | 24,245,121 | 16 | 19 | 19 |  |
| 198 | 17.1 | **BOVEDA ARQUEOLÓGICA** |  | 76.37d | 2008-01-02 | 2008-04-17 |  | 30.24d |  |  | 1130.48h | 24,245,121 | 16.1 | 19 | 19.01 |  |
| 199 | 17.1.1 | Excavacion en tierra manual |  | 9.51d | 2008-01-02 | 2008-01-16 | 35SS+2% | 30.24d | 0d | AYUDANTE [300%] | 228.16h | 2,751,364 | 16.1.1 | 19 | 19.01 | m3 |
| 200 | 17.1.2 | Afirmado compactado e=0,10m |  | 1.1d | 2008-01-16 | 2008-01-17 | 199 | 30.24d | 0d | AYUDANTE | 8.8h | 159,230 | 16.1.2 | 19 | 19.01 | m3 |
| 201 | 17.1.3 | Lleno con arena incluye plastico |  | 2.33d | 2008-01-17 | 2008-01-21 | 200 | 30.24d | 0d | AYUDANTE | 18.64h | 264,943 | 16.1.3 | 19 | 19.01 | m3 |
| 202 | 17.1.4 | Retiro de arena |  | 0.35d | 2008-01-21 | 2008-01-21 | 201 | 30.24d | 0d | AYUDANTE | 2.8h | 126,756 | 16.1.4 | 19 | 19.01 | m3 |
| 203 | 17.1.5 | Losa de concreto reforzado e=0.15 visto con textura ranurado |  | 10.6d | 2008-01-21 | 2008-02-05 | 202 | 30.24d | 0d | AYUDANTE; OFICIAL | 169.6h | 1,860,364 | 16.1.5 | 19 | 19.01 | m2 |
| 204 | 17.1.6 | Zapatas en concreto reforzado de 210 kg/cm2 |  | 0.5d | 2008-02-05 | 2008-02-05 | 203 | 30.24d | 0d | AYUDANTE; OFICIAL | 8h | 177,079 | 16.1.6 | 19 | 19.01 | m3 |
| 205 | 17.1.7 | Pantallas en concreto reforzado de 210 kg/cm2 color ocre |  | 13d | 2008-02-05 | 2008-02-22 | 204 | 30.24d | 0d | AYUDANTE; OFICIAL | 208h | 6,371,326 | 16.1.7 | 19 | 19.01 | m3 |
| 206 | 17.1.8 | Viguetas aereas de 0.15 m x 0.50 m en concreto reforzado 210 kg/cm2 |  | 2d | 2008-02-22 | 2008-02-26 | 205 | 30.24d | 0d | AYUDANTE; OFICIAL | 32h | 418,760 | 16.1.8 | 19 | 19.01 |  |
| 207 | 17.1.9 | Vigas en concreto reforzado de 0.40 m x 0.50 m de 210 kgcm2 |  | 1.2d | 2008-02-26 | 2008-02-28 | 206 | 30.24d | 0d | AYUDANTE; OFICIAL | 19.2h | 326,316 | 16.1.9 | 19 | 19.01 |  |
| 208 | 17.1.10 | Elementos en concreto reforzado de 210 kgcm2 en forma piramidal |  | 4d | 2008-02-28 | 2008-03-05 | 207 | 30.24d | 0d | AYUDANTE; OFICIAL | 64h | 1,416,632 | 16.1.10 | 19 | 19.01 | m3 |
| 209 | 17.1.11 | Carcamo en concreto incluye reja metalica |  | 0.8d | 2008-03-05 | 2008-03-05 | 208 | 30.24d | 0d | AYUDANTE; OFICIAL | 12.8h | 427,344 | 16.1.11 | 19 | 19.01 |  |
| 210 | 17.1.12 | Escalas en concreto de 210 kg/cm2 incluye refuerzo |  | 2.5d | 2008-03-05 | 2008-03-10 | 209 | 30.24d | 0d | AYUDANTE; OFICIAL | 40h | 604,200 | 16.1.12 | 19 | 19.01 | m2 |
| 211 | 17.1.13 | Tapaluz en acero inox para nichos |  | 2d | 2008-03-10 | 2008-03-12 | 210 | 30.24d | 0d | AYUDANTE [50%]; OFICIAL | 24h | 312,046 | 16.1.13 | 19 | 19.01 | glb |
| 212 | 17.1.14 | Bancas en Placas de concreto 210 kg/cm2 empotradas |  | 2.17d | 2008-03-12 | 2008-03-14 | 211 | 30.24d | 0d | AYUDANTE; OFICIAL | 34.72h | 830,941 | 16.1.14 | 19 | 19.01 |  |
| 213 | 17.1.15 | Base en concreto reforzado de 210 kg/cm2 para urna en vidrio |  | 2d | 2008-03-14 | 2008-03-18 | 212 | 30.24d | 0d | AYUDANTE; OFICIAL | 32h | 734,130 | 16.1.15 | 19 | 19.01 |  |
| 214 | 17.1.16 | Caja en concreto reforzado de 21 Mpa 1,2 x 1,2 x 1,8 incluye reja |  | 1d | 2008-03-18 | 2008-03-19 | 213 | 30.24d | 0d | AYUDANTE; OFICIAL | 16h | 699,937 | 16.1.16 | 19 | 19.01 | un |
| 215 | 17.1.17 | Tubo sanitario de 4¨para desagüe cárcamos incluye accesorios |  | 0.18d | 2008-03-19 | 2008-03-19 | 214 | 30.24d | 0d | AYUDANTE [200%]; OFICIAL | 4.32h | 160,992 | 16.1.17 | 19 | 19.01 |  |
| 216 | 17.1.18 | Pasamanos en tuberia AN. 1 1/2" c 22 Circular |  | 4.8d | 2008-03-19 | 2008-03-26 | 215 | 30.24d | 0d | AYUDANTE; OFICIAL | 76.8h | 1,174,560 | 16.1.18 | 19 | 19.01 |  |
| 217 | 17.1.19 | Urna en vidrio de 6 mm. |  | 9d | 2008-03-26 | 2008-04-08 | 216 | 30.24d | 0d | OFICIAL | 72h | 3,230,244 | 16.1.19 | 19 | 19.01 | gl |
| 218 | 17.1.20 | Salida Iluminacion |  | 5d | 2008-04-08 | 2008-04-15 | 217 | 30.24d | 0d | OFICIAL | 40h | 690,690 | 16.1.20 | 19 | 19.01 | un |
| 219 | 17.1.21 | Salida tomacorriente doble |  | 0.33d | 2008-04-15 | 2008-04-15 | 218 | 30.24d | 0d | OFICIAL | 2.64h | 45,347 | 16.1.21 | 19 | 19.01 | un |
| 220 | 17.1.22 | Bomba Extractora Agua de carcamo |  | 2d | 2008-04-15 | 2008-04-17 | 219 | 30.24d | 0d | OFICIAL | 16h | 1,461,920 | 16.1.22 | 19 | 19.01 | un |
| 221 | 18 | fin | milestone | 0d | 2008-06-02 | 2008-06-02 | 220, 196, 186, 139, 109, 92, 51, 82, 77, 110, 38 | 0.24d |  |  |  |  |  |  |  |  |
| 222 | 11 | FIN TOTAL | milestone | 0d | 2008-06-02 | 2008-06-02 | 221 | 0d |  |  |  |  |  |  |  |  |
