# ImportTaskCplan

Schedule from MS Project, 2007-12-13 to 2008-06-02, costs in $.
CMV INGENIERIA EU

## Calendars

- Estándar: Mon-Fri 09:00-13:00, 15:00-19:00; Sat-Sun off.

## Resources

| Resource |
| --- |
| Ayudante |
| Oficial |
| Mano de Obra AA |

## Schedule

| ID | WBS | Task | Type | Duration | Start | Finish | Predecessors | Total slack | Free slack | Resources | Work | Cost | Text4 | Text5 | Text2 | Text1 |
| --- | --- | --- | --- | --- | --- | --- | --- | --- | --- | --- | --- | --- | --- | --- | --- | --- |
| 1 | 4.1.5 | Retiro de sobrantes |  | 14.65d | 2007-12-13 | 2008-01-02 |  | 0d |  |  | 117.2h | 5,305,644 |  |  |  |  |
| 2 | 2 | INICIO | milestone | 0d | 2008-01-02 | 2008-01-02 | 1 | 0d |  |  |  |  |  |  |  |  |
| 3 | 3 | **PRELIMINARES** |  | 2.47d | 2008-01-02 | 2008-01-07 |  | 0d |  |  | 51.52h | 802,782 | 01 | 01 |  |  |
| 4 | 3.1 | **PRELIMINARES** |  | 2.47d | 2008-01-02 | 2008-01-07 |  | 0d |  |  | 51.52h | 802,782 | 01 | 01.01 | 1.1 |  |
| 5 | 3.1.1 | Demolicion andenes y retiro |  | 2.47d | 2008-01-02 | 2008-01-07 | 2 | 0d |  | Ayudante; Oficial | 39.52h | 304,547 | 01 | 01.01 | 1.1.1 | m2 |
| 6 | 3.1.2 | Demolicion de concreto reforzado y retiro escombros |  | 1.5d | 2008-01-03 | 2008-01-07 | 5FF | 0d |  | Ayudante | 12h | 498,235 | 01 | 01.01 | 1.1.2 | m3 |
| 7 | 4 | **CIMENTACION** |  | 69.82d | 2008-01-07 | 2008-04-14 |  | 0d |  |  | 4268.24h | 92,515,875 | 02 | 02 |  |  |
| 8 | 4.1 | **CIMENTACION** |  | 69.82d | 2008-01-07 | 2008-04-14 |  | 0d |  |  | 4268.24h | 92,515,875 | 02 | 02.01 | 2.1 |  |
| 9 | 4.1.1 | Excavacion en tierra hasta 3 mts. |  | 21d | 2008-01-07 | 2008-02-05 | 6 | 84.17d |  | Ayudante [500%] | 840.08h | 10,130,022 | 02 | 02.01 | 2.1.1 | m3 |
| 10 | 4.1.2 | Excavación mecánica |  | 5.89d | 2008-01-07 | 2008-01-15 | 6 | 99.29d |  | Ayudante [500%] | 235.44h | 8,109,530 | 02 | 02.01 | 2.1.2 | m3 |
| 11 | 4.1.3 | Excavación en basura |  | 16.06d | 2008-01-07 | 2008-01-29 | 6 | 0d |  | Ayudante [1000%] | 1284.48h | 16,787,502 | 02 | 02.01 | 2.1.3 | m3 |
| 12 | 4.1.4 | Subbase granular tipo INVIAS |  | 1.1d | 2008-01-29 | 2008-01-30 | 11 | 0d |  | Ayudante; Oficial | 17.6h | 1,200,034 | 02 | 02.01 | 2.1.4 | m3 |
| 13 | 4.1.5 | Afirmado |  | 30.13d | 2008-02-19 | 2008-04-01 | 18 | 2.11d | 0d | Ayudante [150%] | 361.6h | 7,024,758 | 02 | 02.01 | 2.1.5 | m3 |
| 14 | 4.1.6 | Lleno con material seleccionado de excavacion |  | 15.03d | 2008-02-19 | 2008-03-11 | 18 | 0d |  | Ayudante [500%] | 601.04h | 7,253,469 | 02 | 02.01 | 2.1.6 | m3 |
| 15 | 4.1.7 | Retiro de sobrantes |  | 38.67d | 2008-02-19 | 2008-04-14 | 14SS | 0d |  | Ayudante [300%] | 928h | 42,010,560 | 02 | 02.01 | 2.1.7 | m3 |
| 16 | 5 | **INSTALACION SANITARIA PVC** |  | 14d | 2008-01-30 | 2008-02-19 |  | 0d |  |  | 409.6h | 15,211,174 | 13 | 13 |  |  |
| 17 | 5.1 | **INSTALACION SANITARIA PVC** |  | 14d | 2008-01-30 | 2008-02-19 |  | 0d |  |  | 409.6h | 15,211,174 | 13 | 13.01 | 3.1 |  |
| 18 | 5.1.1 | D= 400 mm |  | 14d | 2008-01-30 | 2008-02-19 | 12 | 0d |  | Ayudante; Oficial | 224h | 7,291,760 | 13 | 13.01 | 3.1.1 | ml |
| 19 | 5.1.2 | 0,60 * 0,60 |  | 2.8d | 2008-01-30 | 2008-02-04 | 18SS | 81.22d | 0d | Ayudante; Oficial | 44.8h | 548,804 | 13 | 13.01 | 3.1.2 | un |
| 20 | 5.1.3 | 0,80 * 0,80 |  | 6.8d | 2008-01-30 | 2008-02-08 | 19SS | 81.22d | 0d | Ayudante; Oficial | 108.8h | 1,615,960 | 13 | 13.01 | 3.1.3 | un |
| 21 | 5.1.4 | 1,60*0,70*0,90 |  | 2d | 2008-01-30 | 2008-02-01 | 20SS | 86.02d |  | Ayudante; Oficial | 32h | 5,754,650 | 13 | 13.01 | 3.1.4 | un |
| 22 | 6 | **EXTERIORES** |  | 107.64d | 2008-01-02 | 2008-06-02 |  | 0d |  |  | 6584.56h | 160,002,930 | 18 | 18 |  |  |
| 23 | 6.1 | **EXTERIORES** |  | 107.64d | 2008-01-02 | 2008-06-02 |  | 0d |  |  | 6584.56h | 160,002,930 | 18 | 18.01 | 4.1 |  |
| 24 | 6.1.1 | Señal reglamentaria reflectiva |  | 12d | 2008-01-02 | 2008-01-18 | 2 | 60.29d |  | Oficial | 96h | 1,307,886 | 18 | 18.01 | 4.1.1 | un |
| 25 | 6.1.2 | Perfilado y conformacion de taludes |  | 4.04d | 2008-04-14 | 2008-04-18 | 15, 24 | 0d |  | Ayudante [400%] | 129.12h | 1,262,151 | 18 | 18.01 | 4.1.2 | m2 |
| 26 | 6.1.3 | Adoquin rectangular en concreto de Indural color gris de 6x10x20 |  | 25.03d | 2008-04-16 | 2008-05-21 | 25FS-5% | 0d |  | Ayudante [312%]; Oficial [312%] | 1249.6h | 25,666,784 | 18 | 18.01 | 4.1.3 | m2 |
| 27 | 6.1.4 | Adoquin rectangular en concreto de Indural color jaspeado de 6x10x20 |  | 24.4d | 2008-04-16 | 2008-05-20 | 26SS | 0d |  | Ayudante; Oficial | 390.4h | 8,018,816 | 18 | 18.01 | 4.1.4 | m2 |
| 28 | 6.1.5 | Adoquin rectangular en concreto de Indural color terracota de 6x10x20 en franjas de 50cm |  | 8d | 2008-05-16 | 2008-05-28 | 27FS-1% | 0d |  | Ayudante; Oficial | 128h | 2,629,120 | 18 | 18.01 | 4.1.5 |  |
| 29 | 6.1.6 | Gramoquin en concreto de Indural |  | 4.17d | 2008-05-27 | 2008-06-02 | 28FS-1% | 0d |  | Ayudante [350%]; Oficial [350%] | 233.6h | 3,980,106 | 18 | 18.01 | 4.1.6 | m2 |
| 30 | 6.1.7 | Sardinel prefabricado 210 kg/cm2 de 9x50cm |  | 4.08d | 2008-04-18 | 2008-04-24 | 25 | 27.23d |  | Ayudante; Oficial | 65.28h | 3,395,104 | 18 | 18.01 | 4.1.7 |  |
| 31 | 6.1.8 | Sardinel prefabricado 210 kg/cm2 de 20x50cm |  | 5.8d | 2008-04-18 | 2008-04-28 | 25 | 20.76d | 0d | Ayudante; Oficial | 92.8h | 3,508,768 | 18 | 18.01 | 4.1.8 |  |
| 32 | 6.1.9 | Bordillo vaciado en sitio 210 kg/cm2 de 20x30cm |  | 4.75d | 2008-04-28 | 2008-05-02 | 31 | 20.76d |  | Ayudante; Oficial | 76h | 2,230,790 | 18 | 18.01 | 4.1.9 |  |
| 33 | 6.1.10 | Alfagia para Escaño corrido en concreto 210 kg/cm2 a=0.3m |  | 3.38d | 2008-04-18 | 2008-04-23 | 25 | 4.22d | 0d | Ayudante; Oficial | 54.08h | 662,526 | 18 | 18.01 | 4.1.10 |  |
| 34 | 6.1.11 | escalon en concreto 210 kg/cm2 a=0.3m h=0,15m |  | 3.38d | 2008-04-23 | 2008-04-29 | 33 | 4.22d | 0d | Ayudante; Oficial | 54.08h | 815,670 | 18 | 18.01 | 4.1.11 |  |
| 35 | 6.1.12 | Concreto a la vista zona dura fuente |  | 4.76d | 2008-04-29 | 2008-05-05 | 34 | 4.22d | 0d | Ayudante [500%]; Oficial [500%] | 380.8h | 7,476,532 | 18 | 18.01 | 4.1.12 | m2 |
| 36 | 6.1.13 | Placas en concreto empotradas de 0,90 x 0,90 |  | 1.1d | 2008-05-05 | 2008-05-06 | 35 | 4.22d | 0d | Ayudante; Oficial | 17.6h | 325,578 | 18 | 18.01 | 4.1.13 | un |
| 37 | 6.1.14 | Bancas en Placas en concreto 210 kg/cm2 empotradas |  | 8d | 2008-05-06 | 2008-05-16 | 36 | 4.22d | 0d | Ayudante; Oficial | 128h | 1,694,356 | 18 | 18.01 | 4.1.14 | un |
| 38 | 6.1.15 | Bancas circulares en concreto |  | 8d | 2008-05-06 | 2008-05-16 | 37SS | 4.22d | 0d | Ayudante; Oficial | 128h | 1,643,160 | 18 | 18.01 | 4.1.15 | un |
| 39 | 6.1.16 | Escalas en concreto visto 21 Mpa sobre terreno acceso guaducto |  | 6.48d | 2008-05-16 | 2008-05-27 | 38 | 4.22d |  | Ayudante [300%]; Oficial [300%] | 310.88h | 10,931,000 | 18 | 18.01 | 4.1.16 | m2 |
| 40 | 6.1.17 | Protector de raiz en concreto de 210 kg/cm2 d=1m |  | 2d | 2008-05-09 | 2008-05-13 | 42 | 2.27d | 0.16d | Ayudante [500%]; Oficial [500%] | 160h | 2,491,180 | 18 | 18.01 | 4.1.17 | un |
| 41 | 6.1.18 | Sumidero con rejilla metalica |  | 3.2d | 2008-02-19 | 2008-02-22 | 18 | 67.82d | 0d | Ayudante; Oficial | 51.2h | 9,207,440 | 18 | 18.01 | 4.1.18 |  |
| 42 | 6.1.19 | Muro en bloque de concreto tipo split reforzado con grouting |  | 20.67d | 2008-04-10 | 2008-05-09 | 44 | 2.27d | 0d | Ayudante; Oficial | 330.72h | 5,682,052 | 18 | 18.01 | 4.1.19 | m2 |
| 43 | 6.1.20 | Muro en concreto reforzado |  | 7.43d | 2008-04-10 | 2008-04-22 | 44 | 2.11d | 0d | Ayudante [300%]; Oficial [300%] | 356.8h | 8,302,580 | 18 | 18.01 | 4.1.20 | m3 |
| 44 | 6.1.21 | Viga de cimentacion de 30x30 para muro de confinamiento |  | 4.23d | 2008-04-04 | 2008-04-10 | 45 | 2.11d | 0d | Ayudante; Oficial | 67.68h | 1,574,829 | 18 | 18.01 | 4.1.21 |  |
| 45 | 6.1.22 | Zapata en concreto para muro acceso al guaducto |  | 12d | 2008-03-19 | 2008-04-04 | 13FS-3% | 2.11d | 0d | Ayudante [500%]; Oficial [500%] | 960h | 21,738,000 | 18 | 18.01 | 4.1.22 | m3 |
| 46 | 6.1.23 | Pavimento en concreto patio de maniobras |  | 3d | 2008-02-22 | 2008-02-27 | 12, 41 | 67.82d |  | Mano de Obra AA [300%] | 72h | 7,018,776 | 18 | 18.01 | 4.1.23 | m2 |
| 47 | 6.1.24 | Lecho en piedra y geotextil NT 1600 para gramoquin |  | 10.22d | 2008-04-22 | 2008-05-06 | 43 | 16.54d | 0d | Ayudante; Oficial | 163.52h | 3,267,079 | 18 | 18.01 | 4.1.24 | m3 |
| 48 | 6.1.25 | Tuberia corrugada 110 mm para lecho |  | 1.95d | 2008-05-06 | 2008-05-08 | 47 | 16.54d | 0d | Ayudante; Oficial | 31.2h | 877,734 | 18 | 18.01 | 4.1.25 |  |
| 49 | 6.1.26 | Filtro frances de 40x40 con geotextil para muro acceso al guaducto |  | 0.55d | 2008-05-08 | 2008-05-09 | 48 | 16.54d |  | Ayudante; Oficial | 8.8h | 425,187 | 18 | 18.01 | 4.1.26 | m3 |
| 50 | 6.1.27 | Fuente de agua en concreto, incluye sistema de recirculacion hidraulica |  | 20d | 2008-04-22 | 2008-05-20 | 43 | 4.26d | 0d | Ayudante; Oficial | 320h | 6,580,311 | 18 | 18.01 | 4.1.27 | m2 |
| 51 | 6.1.28 | Cañuela en concreto para fuente |  | 5d | 2008-05-20 | 2008-05-27 | 50 | 4.26d |  | Mano de Obra AA | 40h | 818,200 | 18 | 18.01 | 4.1.28 |  |
| 52 | 6.1.29 | Pasamanos en tubo aguas negras de 2 1/2" para antepecho |  | 2.8d | 2008-04-22 | 2008-04-25 | 43 | 2.11d | 0d | Ayudante; Oficial | 44.8h | 930,790 | 18 | 18.01 | 4.1.29 |  |
| 53 | 6.1.30 | Pasamanos en tubo aguas negras de 2 1/2" con paral en platina metalica |  | 8.6d | 2008-04-25 | 2008-05-07 | 52 | 2.11d | 0d | Ayudante; Oficial | 137.6h | 2,858,855 | 18 | 18.01 | 4.1.30 |  |
| 54 | 6.1.31 | Basurero en acero inóxidable |  | 3d | 2008-05-02 | 2008-05-07 | 53FF | 2.11d | 0d | Oficial | 24h | 1,067,880 | 18 | 18.01 | 4.1.31 | un |
| 55 | 6.1.32 | Totem sobre tumba |  | 4d | 2008-05-07 | 2008-05-13 | 54 | 2.11d | 0d | Oficial | 32h | 1,123,840 | 18 | 18.01 | 4.1.32 | un |
| 56 | 6.1.33 | Arbusto jardineras especie croto |  | 7.5d | 2008-05-13 | 2008-05-23 | 55, 40 | 2.11d | 0d | Oficial | 60h | 1,130,700 | 18 | 18.01 | 4.1.33 | un |
| 57 | 6.1.34 | Arbol en zonas verdes especie leucaena |  | 7.5d | 2008-05-13 | 2008-05-23 | 56SS | 2.11d | 0d | Oficial | 60h | 2,180,700 | 18 | 18.01 | 4.1.34 | un |
| 58 | 6.1.35 | Palma Areca |  | 1.25d | 2008-05-23 | 2008-05-26 | 57 | 2.11d | 0d | Oficial | 10h | 713,450 | 18 | 18.01 | 4.1.35 | un |
| 59 | 6.1.36 | Empradizado en grama |  | 3d | 2008-05-26 | 2008-05-29 | 58 | 2.11d |  | Oficial [500%] | 120h | 6,465,000 | 18 | 18.01 | 4.1.36 | m2 |
| 60 | 11 | FIN | milestone | 0d | 2008-05-30 | 2008-05-30 |  | 0.68d |  |  |  |  |  |  |  |  |
| 61 | 8 | FIN | milestone | 0d | 2008-06-02 | 2008-06-02 | 59, 39, 29, 46, 41, 60 | 0d |  |  |  |  |  |  |  |  |
| 62 | 16 | FIN | milestone | 0d | 2008-02-07 | 2008-02-07 |  | 81.79d |  |  |  |  |  |  |  |  |
| 63 | 18 | fin | milestone | 0d | 2008-06-02 | 2008-06-02 |  | 0.24d |  |  |  |  |  |  |  |  |
| 64 | 11 | FIN TOTAL | milestone | 0d | 2008-06-02 | 2008-06-02 | 60, 61, 62, 63 | 0d |  |  |  |  |  |  |  |  |
