# ImportTaskCplan

Schedule from MS Project, 2007-10-05 to 2008-06-02, costs in $.
CMV INGENIERIA EU

## Calendars

- Estándar: Mon-Fri 09:00-13:00, 15:00-19:00; Sat-Sun off.

## Resources

| Resource |
| --- |
| OFICIAL |
| AYUDANTE |

## Schedule

| ID | WBS | Task | Type | Duration | Start | Finish | Predecessors | Total slack | Free slack | Resources | Work | Cost | Text3 | Text4 | Text5 | Text2 | Text1 |
| --- | --- | --- | --- | --- | --- | --- | --- | --- | --- | --- | --- | --- | --- | --- | --- | --- | --- |
| 1 | 4.1.8 | Concreto 24.5mpa viga de fundacion |  | 8.75d | 2007-10-05 | 2007-10-18 |  | 0d |  |  | 280h | 8,296,325 |  |  |  |  |  |
| 2 | 2 | INICIO | milestone | 0d | 2007-10-18 | 2007-10-18 | 1 | 0d |  |  |  |  |  |  |  |  |  |
| 3 | 3 | **PRELIMINARES** |  | 19.25d | 2007-10-18 | 2007-11-14 |  | 0d |  |  | 34.88h | 1,153,547 | 01 | 01 | 01 |  |  |
| 4 | 3.1 | **PRELIMINARES** |  | 19.25d | 2007-10-18 | 2007-11-14 |  | 0d |  |  | 34.88h | 1,153,547 | 01.01 | 01 | 01.01 | 1.1 |  |
| 5 | 3.1.1 | Demolicion anillo caisson y retiro escombros |  | 0.3d | 2007-11-14 | 2007-11-14 | 15 | 142.78d |  | OFICIAL; AYUDANTE | 4.8h | 81,647 | 01-05 | 01 | 01.01 | 1.1.1 | m3 |
| 6 | 3.1.2 | Cerramiento en tela h=2.1 |  | 1.88d | 2007-10-18 | 2007-10-22 | 2 | 0d |  | AYUDANTE; OFICIAL | 30.08h | 1,071,900 | 01-07 | 01 | 01.01 | 1.1.2 | ml |
| 7 | 4 | **CIMENTACION** |  | 52.6d | 2007-10-22 | 2008-01-03 |  | 0d |  |  | 4253.42h | 101,616,909 | 02 | 02 | 02 |  |  |
| 8 | 4.1 | **CIMENTACION** |  | 52.6d | 2007-10-22 | 2008-01-03 |  | 0d |  |  | 4253.42h | 101,616,909 | 02.01 | 02 | 02.01 | 2.1 |  |
| 9 | 4.1.1 | Excavacion caissons hasta 12 mts. |  | 16.67d | 2007-10-25 | 2007-11-19 | 6, 11 | 0d |  | OFICIAL [300%]; AYUDANTE [900%] | 1600h | 18,710,200 | 02-01 | 02 | 02.01 | 2.1.1 | m3 |
| 10 | 4.1.2 | Excavacion en tierra hasta 3 mts. |  | 3.7d | 2007-11-14 | 2007-11-20 | 15 | 0d |  | AYUDANTE [500%] | 148.16h | 1,786,600 | 02-02 | 02 | 02.01 | 2.1.2 | m3 |
| 11 | 4.1.3 | Excavación mecánica |  | 3.1d | 2007-10-22 | 2007-10-25 | 6 | 0d |  | AYUDANTE [50%] | 12.4h | 427,180 | 02-03 | 02 | 02.01 | 2.1.3 | m3 |
| 12 | 4.1.4 | Lleno con material seleccionado de excavacion |  | 16.38d | 2007-12-11 | 2008-01-03 | 16 | 0d |  | AYUDANTE | 131.04h | 1,581,039 | 02-07 | 02 | 02.01 | 2.1.4 | m3 |
| 13 | 4.1.5 | Retiro de sobrantes |  | 14.65d | 2007-12-13 | 2008-01-02 | 12FS-9% | 0d |  | AYUDANTE | 117.2h | 5,305,644 | 02-08 | 02 | 02.01 | 2.1.5 | m3 |
| 14 | 2 | INICIO | milestone | 0d | 2008-01-02 | 2008-01-02 | 13 | 0d |  |  |  |  |  |  |  |  |  |
| 15 | 4.1.7 | Concreto 21mpa anillos de caisson |  | 12.3d | 2007-10-29 | 2007-11-14 | 9FS-9% | 0d |  | AYUDANTE [300%]; OFICIAL [300%] | 590.4h | 12,020,913 | 02-09 | 02 | 02.01 | 2.1.6 | m3 |
| 16 | 4.1.8 | Concreto 24.5mpa caisson fuste |  | 15.45d | 2007-11-20 | 2007-12-11 | 10 | 0d |  | OFICIAL [200%]; AYUDANTE [466%] | 823.18h | 31,660,861 | 02-10 | 02 | 02.01 | 2.1.7 | m3 |
| 17 | 4.1.9 | Concreto 14mpa solados |  | 8d | 2007-11-30 | 2007-12-12 | 18FS-9% | 0.68d | 0d | OFICIAL [10%]; AYUDANTE [30%] | 25.6h | 392,894 | 02-11 | 02 | 02.01 | 2.1.8 | m3 |
| 18 | 4.1.10 | Concreto 24.5mpa dados |  | 7d | 2007-11-29 | 2007-12-10 | 16FS-5% | 0.68d | 0d | AYUDANTE; OFICIAL | 112h | 3,426,910 | 02-12 | 02 | 02.01 | 2.1.9 | m3 |
| 19 | 4.1.11 | Concreto 24.5mpa viga de fundacion |  | 4.34d | 2007-12-12 | 2007-12-18 | 17 | 0.68d | 0d | AYUDANTE; OFICIAL | 69.44h | 2,057,489 | 02-13 | 02 | 02.01 | 2.1.10 | m3 |
| 20 | 4.1.12 | Acero refuerzo 420mpa |  | 39d | 2007-10-29 | 2007-12-21 | 15SS | 116.38d |  | AYUDANTE [200%] | 624h | 24,247,179 | 02-21 | 02 | 02.01 | 2.1.11 | kg |
| 21 | 5 | **ESTRUCTURA** |  | 73.06d | 2007-12-18 | 2008-03-31 |  | 0.68d |  |  | 4563.87h | 155,397,243 | 03 | 03 | 03 |  |  |
| 22 | 5.1 | **ESTRUCTURA** |  | 73.06d | 2007-12-18 | 2008-03-31 |  | 0.68d |  |  | 4563.87h | 155,397,243 | 03.01 | 03 | 03.01 | 3.1 |  |
| 23 | 5.1.1 | Concreto 24.5 mpa columnas rectangulares a la vista lisas |  | 55.55d | 2007-12-18 | 2008-03-05 | 19 | 0.68d | 0d | AYUDANTE [200%]; OFICIAL [200%] | 1777.6h | 47,088,018 | 03-01 | 03 | 03.01 | 3.1.1 | m3 |
| 24 | 5.1.2 | Concreto 24.5mpa viga elevada a la vista lisa |  | 55d | 2007-12-26 | 2008-03-12 | 23FS-9% | 2.34d | 0d | AYUDANTE [22%]; OFICIAL [22%] | 193.6h | 5,215,507 | 03-02 | 03 | 03.01 | 3.1.2 | m3 |
| 25 | 5.1.3 | Concreto 24.5 mpa losa lamina colaborante a la vista lisa |  | 55.5d | 2008-01-03 | 2008-03-20 | 24FS-9% | 2.34d | 0d | OFICIAL [56%]; AYUDANTE [150%] | 912.51h | 36,030,008 | 03-05 | 03 | 03.01 | 3.1.3 | m2 |
| 26 | 5.1.4 | Malla electrosoldada 15x15 5mm |  | 62d | 2008-01-03 | 2008-03-31 | 25SS | 45.56d |  | AYUDANTE [2%]; OFICIAL [2%] | 19.84h | 3,058,374 | 03-06 | 03 | 03.01 | 3.1.4 | m2 |
| 27 | 5.1.5 | Acero refuerzo 420mpa |  | 51.88d | 2007-12-18 | 2008-02-28 | 23SS | 66.73d |  | AYUDANTE [400%] | 1660.32h | 64,005,336 | 03-10 | 03 | 03.01 | 3.1.5 | kg |

| ID | WBS | Task | Type | Duration | Start | Finish | Predecessors | Total slack | Free slack | Resources | Work | Cost | Text3 | Text4 | Text5 | Text2 | Text1 |
| --- | --- | --- | --- | --- | --- | --- | --- | --- | --- | --- | --- | --- | --- | --- | --- | --- | --- |
| 28 | 6 | **CUBIERTA Y ESTRUCTURAS METÁLICAS** |  | 62.38d | 2008-03-05 | 2008-05-30 |  | 0.68d |  |  | 9659.52h | 216,596,213 | 04 | 04 | 04 |  |  |
| 29 | 6.1 | **CUBIERTA Y ESTRUCTURAS METÁLICAS** |  | 62.38d | 2008-03-05 | 2008-05-30 |  | 0.68d |  |  | 9659.52h | 216,596,213 | 04.01 | 04 | 04.01 | 4.1 |  |
| 30 | 6.1.1 | Platina de anclaje estructura metalica (incluye pintura) |  | 2.3d | 2008-03-05 | 2008-03-07 | 23 | 0.68d | 0d | AYUDANTE; OFICIAL | 36.8h | 902,152 | 04-01 | 04 | 04.01 | 4.1.1 | kg |
| 31 | 6.1.2 | Estructura metálica para rampas |  | 45.44d | 2008-03-07 | 2008-05-12 | 30 | 0.68d | 0d | AYUDANTE [1200%]; OFICIAL [1200%] | 8724.16h | 179,705,600 | 04-03 | 04 | 04.01 | 4.1.2 | kg |
| 32 | 6.1.3 | Apoyo a calados en superboard |  | 44.87d | 2008-03-14 | 2008-05-16 | 31FS-9% | 0.68d | 0d | AYUDANTE [70%]; OFICIAL [70%] | 502.56h | 10,353,024 | 04-05 | 04 | 04.01 | 4.1.3 | kg |
| 33 | 6.1.4 | Cubierta tipo sanduche deck 500 c |  | 7.73d | 2008-05-16 | 2008-05-27 | 32 | 0.68d | 0d | OFICIAL [300%] | 185.44h | 22,779,200 | 04-06 | 04 | 04.01 | 4.1.4 | m2 |
| 34 | 6.1.5 | Alfajia doble metalica cal 24 Long desarrollo 0,5 m |  | 4.35d | 2008-05-23 | 2008-05-29 | 33FS-3% | 0.68d | 0d | AYUDANTE [200%]; OFICIAL [200%] | 139.2h | 1,631,511 | 04-07 | 04 | 04.01 | 4.1.5 |  |
| 35 | 6.1.6 | Remates cubierta en manto asfaltico e=2mm, 1 de desarrollo 0.30 |  | 3.66d | 2008-05-23 | 2008-05-29 | 34SS | 0.68d | 0d | AYUDANTE; OFICIAL | 58.56h | 1,018,710 | 04-09 | 04 | 04.01 | 4.1.6 |  |
| 36 | 6.1.7 | Canal en lamina galvanizada cal 24 l de desarrollo 1 mts |  | 1.6d | 2008-05-29 | 2008-05-30 | 35 | 0.68d | 0d | AYUDANTE [50%]; OFICIAL [50%] | 12.8h | 206,016 | 04-10 | 04 | 04.01 | 4.1.7 |  |
| 37 | 7 | **MAMPOSTERIA Y MUROS LIVIANOS** |  | 45.79d | 2008-03-20 | 2008-05-23 |  | 2.34d |  |  | 3864h | 69,471,507 | 05 | 05 | 05 |  |  |
| 38 | 7.1 | **MAMPOSTERIA Y MUROS LIVIANOS** |  | 45.79d | 2008-03-20 | 2008-05-23 |  | 2.34d |  |  | 3864h | 69,471,507 | 05.01 | 05 | 05.01 | 5.1 |  |
| 39 | 7.1.1 | Antepecho Superboard 10 mm (Rampas) |  | 23.62d | 2008-03-20 | 2008-04-23 | 25 | 2.34d | 0d | OFICIAL [400%]; AYUDANTE [800%] | 2268h | 29,959,335 | 05-07 | 05 | 05.01 | 5.1.1 | m2 |
| 40 | 7.1.2 | Calado en superboard 10mm (tipo existente)ver detalle |  | 22.17d | 2008-04-23 | 2008-05-23 | 39, 32FS-5% | 6.27d |  | OFICIAL [300%]; AYUDANTE [600%] | 1596h | 39,512,172 | 05-08 | 05 | 05.01 | 5.1.2 | m2 |
| 41 | 8 | **PISOS Y ENCHAPES** |  | 48.74d | 2008-03-20 | 2008-05-28 |  | 3.32d |  |  | 2543.52h | 30,683,313 | 08 | 08 | 08 |  |  |
| 42 | 8.1 | **PISOS Y ENCHAPES** |  | 48.74d | 2008-03-20 | 2008-05-28 |  | 3.32d |  |  | 2543.52h | 30,683,313 | 08.01 | 08 | 08.01 | 6.1 |  |
| 43 | 8.1.1 | Piso en grano lavado No 3 color beige y base blanca para rampas |  | 24d | 2008-04-15 | 2008-05-19 | 45FS-5% | 3.32d | 0d | AYUDANTE [200%]; OFICIAL [200%] | 768h | 15,137,712 | 08-06 | 08 | 08.01 | 6.1.1 | m2 |
| 44 | 8.1.2 | Guardaescoba en grano lavado N. 2 color beige en base blanca para rampas |  | 18.75d | 2008-05-01 | 2008-05-28 | 43FS-5% | 3.32d | 2.64d | AYUDANTE [400%]; OFICIAL [400%] | 1199.68h | 9,965,025 | 08-09 | 08 | 08.01 | 6.1.2 |  |
| 45 | 8.1.3 | Mortero de nivelacion 1:3 |  | 35.99d | 2008-03-20 | 2008-05-09 | 25 | 3.32d | 0d | AYUDANTE; OFICIAL | 575.84h | 5,580,576 | 08-16 | 08 | 08.01 | 6.1.3 | m² |
| 46 | 9 | **CARPINTERIA METALICA** |  | 26.09d | 2008-04-23 | 2008-05-29 |  | 2.34d |  |  | 892h | 17,488,504 | 10 | 10 | 10 |  |  |
| 47 | 9.1 | **CARPINTERIA METALICA** |  | 26.09d | 2008-04-23 | 2008-05-29 |  | 2.34d |  |  | 892h | 17,488,504 | 10.01 | 10 | 10.01 | 7.1 |  |
| 48 | 9.1.1 | Pasamanos en tubo de aguas negras 2" con anticorrosivo y acabado esmalte color aluminio |  | 26.09d | 2008-04-23 | 2008-05-29 | 39 | 2.34d | 1.66d | AYUDANTE [200%]; OFICIAL [200%] | 834.88h | 16,356,754 | 10-05 | 10 | 10.01 | 7.1.1 |  |
| 49 | 9.1.2 | Dilatacion entre edificio en Super Board |  | 3.57d | 2008-04-23 | 2008-04-28 | 39 | 24.86d |  | AYUDANTE; OFICIAL | 57.12h | 1,131,750 | 10-20 | 10 | 10.01 | 7.1.2 |  |
| 50 | 10 | **INSTALACION SANITARIA PVC** |  | 32.73d | 2008-03-20 | 2008-05-06 |  | 19.33d |  |  | 68.32h | 1,750,376 | 13 | 13 | 13 |  |  |
| 51 | 10.1 | **INSTALACION SANITARIA PVC** |  | 32.73d | 2008-03-20 | 2008-05-06 |  | 19.33d |  |  | 68.32h | 1,750,376 | 13.01 | 13 | 13.01 | 8.1 |  |
| 52 | 10.1.1 | D= 4" |  | 1.28d | 2008-03-20 | 2008-03-21 | 25 | 19.33d | 0d | OFICIAL; AYUDANTE [200%] | 30.72h | 1,144,832 | 13-03 | 13 | 13.01 | 8.1.1 | ml |
| 53 | 10.1.2 | D= 4" |  | 26.67d | 2008-03-21 | 2008-04-29 | 52FS-3% | 19.33d | 0d | AYUDANTE [3%]; OFICIAL [3%] | 12.8h | 266,348 | 13-06 | 13 | 13.01 | 8.1.2 | un |
| 54 | 10.1.3 | 0,60 * 0,60 |  | 2.33d | 2008-04-29 | 2008-05-01 | 53 | 19.33d | 0d | AYUDANTE [30%]; OFICIAL [30%] | 11.2h | 137,201 | 13-14 | 13 | 13.01 | 8.1.3 | un |
| 55 | 10.1.4 | 0,80 * 0,80 |  | 2.83d | 2008-05-01 | 2008-05-06 | 54 | 19.33d | 18.65d | AYUDANTE [30%]; OFICIAL [30%] | 13.6h | 201,995 | 13-15 | 13 | 13.01 | 8.1.4 | un |
| 56 | 11 | FIN | milestone | 0d | 2008-05-30 | 2008-05-30 | 55, 48, 44, 36, 34 | 0.68d |  |  |  |  |  |  |  |  |  |
| 57 | 11 | FIN TOTAL | milestone | 0d | 2008-06-02 | 2008-06-02 | 56 | 0d |  |  |  |  |  |  |  |  |  |
| 58 | 8 | FIN | milestone | 0d | 2008-06-02 | 2008-06-02 | 56 | 0d |  |  |  |  |  |  |  |  |  |
