# ImportTaskCplan

Schedule from MS Project, 2007-09-03 to 2008-06-02, costs in $.
CMV INGENIERIA EU

## Calendars

- Estándar: Mon-Fri 09:00-13:00, 15:00-19:00; Sat-Sun off.

## Resources

| Resource |
| --- |
| OFICIAL |
| AYUDANTE |

## Schedule

| ID | WBS | Task | Type | Duration | Start | Finish | Predecessors | Total slack | Free slack | Resources | Work | Cost | Text3 | Text4 | Text5 | Text2 | Text1 |
| --- | --- | --- | --- | --- | --- | --- | --- | --- | --- | --- | --- | --- | --- | --- | --- | --- | --- |
| 1 | 2.1.1 | Planeación de obra |  | 0.5mo | 2007-09-03 | 2007-09-14 |  | 0d |  |  | 160h | 2,350,000 |  |  |  |  |  |
| 2 | 2 | INICIO | milestone | 0d | 2007-09-17 | 2007-09-17 | 1 | 0d |  |  |  |  |  |  |  |  |  |
| 3 | 3 | **PRELIMINARES** |  | 2.58d | 2007-09-17 | 2007-09-19 |  | 0d |  |  | 41.28h | 1,472,076 | 01 | 01 | 01 |  |  |
| 4 | 3.1 | **PRELIMINARES** |  | 2.58d | 2007-09-17 | 2007-09-19 |  | 0d |  |  | 41.28h | 1,472,076 | 01.01 | 01 | 01.01 | 1.1 |  |
| 5 | 3.1.1 | Cerramiento en tela h=2.1 |  | 2.58d | 2007-09-17 | 2007-09-19 | 2 | 0d |  | OFICIAL; AYUDANTE | 41.28h | 1,472,076 | 01-07 | 01 | 01.01 | 1.1.1 | ml |
| 6 | 4 | **CIMENTACION** |  | 27.43d | 2007-09-19 | 2007-10-29 |  | 0d |  |  | 1844h | 50,989,064 | 02 | 02 | 02 |  |  |
| 7 | 4.1 | **CIMENTACION** |  | 27.43d | 2007-09-19 | 2007-10-29 |  | 0d |  |  | 1844h | 50,989,064 | 02.01 | 02 | 02.01 | 2.1 |  |
| 8 | 4.1.1 | Excavacion en tierra hasta 3 mts. |  | 3.7d | 2007-09-19 | 2007-09-25 | 5 | 179.29d |  | AYUDANTE [500%] | 148.16h | 1,786,600 | 02-02 | 02 | 02.01 | 2.1.1 | m3 |
| 9 | 4.1.2 | Excavación mecánica |  | 3.58d | 2007-09-19 | 2007-09-25 | 5 | 0d |  | AYUDANTE | 28.64h | 985,270 | 02-03 | 02 | 02.01 | 2.1.2 | m3 |
| 10 | 4.1.3 | Excavación en basura |  | 5.14d | 2007-09-21 | 2007-09-28 | 9FS-5% | 0d |  | AYUDANTE | 41.12h | 537,678 | 02-04 | 02 | 02.01 | 2.1.3 | m3 |
| 11 | 4.1.4 | Afirmado |  | 6d | 2007-10-11 | 2007-10-19 | 12FS-5% | 79.48d | 0d | AYUDANTE | 48h | 932,490 | 02-06 | 02 | 02.01 | 2.1.4 | m3 |
| 12 | 4.1.5 | Lleno con material seleccionado de excavacion |  | 7.03d | 2007-10-05 | 2007-10-16 | 17 | 79.48d | 0d | AYUDANTE [500%] | 281.04h | 3,391,389 | 02-07 | 02 | 02.01 | 2.1.5 | m3 |
| 13 | 4.1.6 | Retiro de sobrantes |  | 8.75d | 2007-10-05 | 2007-10-18 | 17 | 162.03d |  | AYUDANTE [60%] | 42h | 1,901,340 | 02-08 | 02 | 02.01 | 2.1.6 | m3 |
| 14 | 4.1.7 | Concreto 14mpa solados |  | 12d | 2007-09-25 | 2007-10-11 | 10FS-5% | 0d |  | AYUDANTE [60%]; OFICIAL [20%] | 76.8h | 1,178,682 | 02-11 | 02 | 02.01 | 2.1.7 | m3 |
| 15 | 4.1.8 | Concreto 24.5mpa viga de fundacion |  | 8.75d | 2007-10-05 | 2007-10-18 | 17 | 0d |  | AYUDANTE [200%]; OFICIAL [200%] | 280h | 8,296,325 | 02-13 | 02 | 02.01 | 2.1.8 | m3 |
| 16 | 2 | INICIO | milestone | 0d | 2007-10-18 | 2007-10-18 | 15 | 0d |  |  |  |  |  |  |  |  |  |
| 17 | 4.1.10 | Concreto 24.5mpa zapatas |  | 6.66d | 2007-09-27 | 2007-10-05 | 14FS-9% | 0d |  | AYUDANTE [300%]; OFICIAL [300%] | 319.52h | 11,923,969 | 02-14 | 02 | 02.01 | 2.1.9 | m3 |
| 18 | 4.1.11 | Losa de contrapiso e=0.10 m. |  | 7.5d | 2007-10-17 | 2007-10-29 | 11FS-3% | 155.56d |  | AYUDANTE [200%]; OFICIAL [200%] | 240.16h | 7,005,375 | 02-15 | 02 | 02.01 | 2.1.10 | m2 |
| 19 | 4.1.12 | Acero refuerzo 420mpa |  | 14.11d | 2007-09-28 | 2007-10-18 | 10 | 161.96d |  | AYUDANTE [300%] | 338.56h | 13,049,946 | 02-21 | 02 | 02.01 | 2.1.11 | kg |
| 20 | 5 | **ESTRUCTURA** |  | 49.95d | 2007-10-18 | 2007-12-27 |  | 3d |  |  | 7807.55h | 244,346,948 | 03 | 03 | 03 |  |  |
| 21 | 5.1 | **ESTRUCTURA** |  | 49.95d | 2007-10-18 | 2007-12-27 |  | 3d |  |  | 7807.55h | 244,346,948 | 03.01 | 03 | 03.01 | 3.1 |  |
| 22 | 5.1.1 | Concreto 24.5 mpa columnas rectangulares a la vista lisas |  | 37.77d | 2007-10-18 | 2007-12-11 | 15 | 3d | 0d | AYUDANTE [300%]; OFICIAL [300%] | 1812.8h | 48,020,454 | 03-01 | 03 | 03.01 | 3.1.1 | m3 |
| 23 | 5.1.2 | Concreto 24.5 mpa losa aligerada a la vista lisa |  | 37.18d | 2007-10-24 | 2007-12-14 | 22FS-9% | 3d | 0d | OFICIAL [450%]; AYUDANTE [720%] | 3479.63h | 98,302,368 | 03-04 | 03 | 03.01 | 3.1.2 | m2 |
| 24 | 5.1.3 | Malla electrosoldada 15x15 5mm |  | 33d | 2007-10-24 | 2007-12-10 | 23SS | 125.25d |  | AYUDANTE [7%]; OFICIAL [7%] | 36.96h | 5,674,218 | 03-06 | 03 | 03.01 | 3.1.3 | m2 |
| 25 | 5.1.4 | Alfajía en concreto para antepechos y ventaneria |  | 2.71d | 2007-12-24 | 2007-12-27 | 30 | 95.82d | 0d | AYUDANTE; OFICIAL | 43.36h | 509,162 | 03-07 | 03 | 03.01 | 3.1.4 |  |
| 26 | 5.1.5 | Alfajía en concreto para antepechos y ventaneria sistemas |  | 4.71d | 2007-12-20 | 2007-12-27 | 25FF | 112.08d |  | AYUDANTE; OFICIAL | 75.36h | 884,334 | 03-08 | 03 | 03.01 | 3.1.5 |  |
| 27 | 5.1.6 | Acero refuerzo 420mpa |  | 40.13d | 2007-10-18 | 2007-12-13 | 22SS | 121.9d |  | AYUDANTE [735%] | 2359.44h | 90,956,412 | 03-10 | 03 | 03.01 | 3.1.6 | kg |

| ID | WBS | Task | Duration | Start | Finish | Predecessors | Total slack | Free slack | Resources | Work | Cost | Text3 | Text4 | Text5 | Text2 | Text1 |
| --- | --- | --- | --- | --- | --- | --- | --- | --- | --- | --- | --- | --- | --- | --- | --- | --- |
| 28 | 6 | **MAMPOSTERIA Y MUROS LIVIANOS** | 59.47d | 2007-10-30 | 2008-01-21 |  | 3d |  |  | 1460.32h | 24,003,617 | 05 | 05 | 05 |  |  |
| 29 | 6.1 | **MAMPOSTERIA Y MUROS LIVIANOS** | 59.47d | 2007-10-30 | 2008-01-21 |  | 3d |  |  | 1460.32h | 24,003,617 | 05.01 | 05 | 05.01 | 4.1 |  |
| 30 | 6.1.1 | Muro en ladrillo farol | 39.75d | 2007-10-30 | 2007-12-24 | 23FS-9% | 3d | 0d | AYUDANTE [150%]; OFICIAL [150%] | 953.92h | 14,302,977 | 05-03 | 05 | 05.01 | 4.1.1 | m2 |
| 31 | 6.1.2 | Cielo falso de panel yeso de 12.7 mm tipo Gyplac junta perdida | 31.65d | 2007-12-06 | 2008-01-21 | 30FS-3% | 13.27d | 0d | AYUDANTE; OFICIAL | 506.4h | 9,700,640 | 05-10 | 05 | 05.01 | 4.1.2 | m2 |
| 32 | 7 | **REVOQUES** | 26.47d | 2007-11-20 | 2007-12-27 |  | 30.38d |  |  | 423.52h | 4,834,256 | 06 | 06 | 06 |  |  |
| 33 | 7.1 | **REVOQUES** | 26.47d | 2007-11-20 | 2007-12-27 |  | 30.38d |  |  | 423.52h | 4,834,256 | 06.01 | 06 | 06.01 | 5.1 |  |
| 34 | 7.1.1 | Revoques para muros en ladrillo farol | 26.47d | 2007-11-20 | 2007-12-27 | 30FS-6% | 30.38d | 0d | AYUDANTE; OFICIAL | 423.52h | 4,834,256 | 06-01 | 06 | 06.01 | 5.1.1 | m2 |
| 35 | 8 | **ACABADOS PARA MUROS INTERIORES Y EXTERIORES** | 21.98d | 2007-12-24 | 2008-01-23 |  | 92.81d |  |  | 535.68h | 10,025,469 | 07 | 07 | 07 |  |  |
| 36 | 8.1 | **ACABADOS PARA MUROS INTERIORES Y EXTERIORES** | 21.98d | 2007-12-24 | 2008-01-23 |  | 92.81d |  |  | 535.68h | 10,025,469 | 07.01 | 07 | 07.01 | 6.1 |  |
| 37 | 8.1.1 | Pintura cielo raso vinilo tipo 1, blanca 3 manos | 15.2d | 2007-12-28 | 2008-01-18 | 31FS-5% | 95.69d |  | AYUDANTE; OFICIAL | 243.2h | 3,750,600 | 07-01 | 07 | 07.01 | 6.1.1 | m2 |
| 38 | 8.1.2 | Pintura texturada hidrorepelente tipo silcoplast para muros de fachada en ladrillo | 7.29d | 2007-12-24 | 2008-01-03 | 30 | 98.79d | 0d | AYUDANTE; OFICIAL | 116.64h | 2,763,999 | 07-02 | 07 | 07.01 | 6.1.2 | m2 |
| 39 | 8.1.3 | Pintura tipo 1 Blanca 3 manos se aplicara en los muros interiores | 21.98d | 2007-12-24 | 2008-01-23 | 30 | 92.81d |  | AYUDANTE [50%]; OFICIAL [50%] | 175.84h | 3,510,870 | 07-03 | 07 | 07.01 | 6.1.3 | m2 |
| 40 | 9 | **PISOS Y ENCHAPES** | 52.59d | 2007-11-05 | 2008-01-16 |  | 17.43d |  |  | 2611.52h | 43,672,495 | 08 | 08 | 08 |  |  |
| 41 | 9.1 | **PISOS Y ENCHAPES** | 52.59d | 2007-11-05 | 2008-01-16 |  | 17.43d |  |  | 2611.52h | 43,672,495 | 08.01 | 08 | 08.01 | 7.1 |  |
| 42 | 9.1.1 | Recubrimiento impermeable con manto XT 500 de FIBERGLASS para terraza | 20.9d | 2007-11-30 | 2007-12-31 | 45 | 110.34d |  | AYUDANTE; OFICIAL | 334.4h | 4,201,736 | 08-02 | 08 | 08.01 | 7.1.1 | m2 |
| 43 | 9.1.2 | Bocapuerta de 10 cm.en granito pulido color beig, dilataciones en bronce | 1.25d | 2008-01-15 | 2008-01-16 | 47 | 97.97d | 16.18d | AYUDANTE; OFICIAL | 20h | 288,240 | 08-03 | 08 | 08.01 | 7.1.2 |  |
| 44 | 9.1.3 | Plaquetas prefabicadas en concreto de 80 cm x 80 cm para acabado de piso terraza | 8.71d | 2008-01-03 | 2008-01-15 | 38, 69 | 98.79d | 17d | AYUDANTE [300%]; OFICIAL [300%] | 418.08h | 7,241,014 | 08-04 | 08 | 08.01 | 7.1.3 | m2 |
| 45 | 9.1.4 | Mortero 1:3 impermeabilizado con sika 1 para placa de terraza sobre aula de sistemas | 14.92d | 2007-11-09 | 2007-11-30 | 46FF | 110.34d | 0d | AYUDANTE; OFICIAL | 238.72h | 3,790,633 | 08-15 | 08 | 08.01 | 7.1.4 | m2 |
| 46 | 9.1.5 | Mortero de nivelacion 1:3 | 19.32d | 2007-11-05 | 2007-11-30 | 30FS-9% | 17.43d | 0d | AYUDANTE [200%]; OFICIAL [200%] | 618.4h | 5,993,952 | 08-16 | 08 | 08.01 | 7.1.5 | m² |
| 47 | 9.1.6 | Piso en granito pulido color beige base blanca incluye dilataciones en aluminio para aulas de sistemas | 32.02d | 2007-11-30 | 2008-01-15 | 46 | 17.43d | 0d | OFICIAL; AYUDANTE [199%] | 765.92h | 19,856,160 | 08-18 | 08 | 08.01 | 7.1.6 | m2 |
| 48 | 9.1.7 | Guardaescoba en granito pulido aulas de sistemas | 30d | 2007-12-03 | 2008-01-14 | 47FS-9.5% | 99.64d | 17.85d | OFICIAL [30%]; AYUDANTE [60%] | 216h | 2,300,760 | 08-19 | 08 | 08.01 | 7.1.7 |  |
| 49 | 10 | **CARPINTERIA METALICA** | 6d | 2007-12-24 | 2008-01-01 |  | 108.79d |  |  | 211.2h | 3,156,668 | 10 | 10 | 10 |  |  |
| 50 | 10.1 | **CARPINTERIA METALICA** | 6d | 2007-12-24 | 2008-01-01 |  | 108.79d |  |  | 211.2h | 3,156,668 | 10.01 | 10 | 10.01 | 8.1 |  |
| 51 | 10.1.1 | Pasamanos en tubo aguas negras de 2'' con anticorrosivo y acabado en pintura de esmalte color aluminio | 6d | 2007-12-24 | 2008-01-01 | 30 | 108.79d |  | AYUDANTE; OFICIAL | 96h | 1,881,288 | 10-05 | 10 | 10.01 | 8.1.1 |  |
| 52 | 10.1.2 | Puerta tipo p-7 lamina | 4.8d | 2007-12-24 | 2007-12-31 | 30 | 109.99d |  | AYUDANTE; OFICIAL [200%] | 115.2h | 1,275,380 | 10-13 | 10 | 10.01 | 8.1.2 | un |

| ID | WBS | Task | Duration | Start | Finish | Predecessors | Total slack | Free slack | Resources | Work | Cost | Text3 | Text4 | Text5 | Text2 | Text1 |
| --- | --- | --- | --- | --- | --- | --- | --- | --- | --- | --- | --- | --- | --- | --- | --- | --- |
| 53 | 11 | **CARPINTERIA EN ALUMINIO** | 16.26d | 2007-12-27 | 2008-01-18 |  | 95.82d |  |  | 933.2h | 69,910,002 | 11 | 11 | 11 |  |  |
| 54 | 11.1 | **CARPINTERIA EN ALUMINIO** | 16.26d | 2007-12-27 | 2008-01-18 |  | 95.82d |  |  | 933.2h | 69,910,002 | 11.01 | 11 | 11.01 | 9.1 |  |
| 55 | 11.1.1 | Ventana tipo v-3 sistemas | 16.26d | 2007-12-27 | 2008-01-18 | 34FS-3%, 25 | 95.82d | 0d | AYUDANTE [200%]; OFICIAL [200%] | 520.32h | 13,578,924 | 11-05 | 11 | 11.01 | 9.1.1 | un |
| 56 | 11.1.2 | Ventana tipo v-9 interior sala sistemas | 16.16d | 2007-12-27 | 2008-01-18 | 55SS | 95.92d | 0d | AYUDANTE [43%]; OFICIAL [43%] | 111.2h | 2,907,984 | 11-12 | 11 | 11.01 | 9.1.2 | un |
| 57 | 11.1.3 | Cortasol aerobrise 200 aluzinc 0.5mm horizontal | 15.99d | 2007-12-27 | 2008-01-18 | 56SS | 96.01d | 0d | OFICIAL [136%] | 173.92h | 34,140,450 | 11-20 | 11 | 11.01 | 9.1.3 | m2 |
| 58 | 11.1.4 | Cortasol aerobrise T234 aluzinc en salas de sistemas | 8.1d | 2007-12-27 | 2008-01-08 | 57SS | 96.01d | 0d | OFICIAL [20%] | 12.96h | 5,007,240 | 11-21 | 11 | 11.01 | 9.1.4 | m2 |
| 59 | 11.1.5 | Pergola aluminio tipo 84r de hunter douglas modulo sistemas. | 7.97d | 2008-01-08 | 2008-01-18 | 58 | 96.01d |  | OFICIAL [180%] | 114.8h | 14,275,404 | 11-22 | 11 | 11.01 | 9.1.5 | m2 |
| 60 | 12 | **INSTALACION SANITARIA PVC** | 12.18d | 2007-09-28 | 2007-10-16 |  | 155.18d |  |  | 206.08h | 3,952,983 | 13 | 13 | 13 | 10 |  |
| 61 | 12.1 | **INSTALACION SANITARIA PVC** | 12.18d | 2007-09-28 | 2007-10-16 |  | 155.18d |  |  | 206.08h | 3,952,983 | 13.01 | 13 | 13.01 | 10.1 |  |
| 62 | 12.1.1 | D=3" | 0.3d | 2007-09-28 | 2007-09-28 | 10 | 155.18d | 0d | AYUDANTE [200%]; OFICIAL | 7.2h | 213,840 | 13-02 | 13 | 13.01 | 10.1.1 | ml |
| 63 | 12.1.2 | D= 4" | 1.1d | 2007-09-28 | 2007-10-01 | 62 | 155.18d | 0d | OFICIAL; AYUDANTE [200%] | 26.4h | 983,840 | 13-03 | 13 | 13.01 | 10.1.2 | ml |
| 64 | 12.1.3 | D= 2" | 0.4d | 2007-10-01 | 2007-10-02 | 63 | 155.18d | 0d | AYUDANTE; OFICIAL | 6.4h | 81,038 | 13-04 | 13 | 13.01 | 10.1.3 | un |
| 65 | 12.1.4 | D= 4" | 1.2d | 2007-10-02 | 2007-10-03 | 64 | 155.18d | 0d | AYUDANTE; OFICIAL | 19.2h | 399,522 | 13-06 | 13 | 13.01 | 10.1.4 | un |
| 66 | 12.1.5 | D= 110 mm | 2.63d | 2007-10-03 | 2007-10-08 | 65 | 155.18d | 0d | AYUDANTE; OFICIAL | 42.08h | 552,552 | 13-07 | 13 | 13.01 | 10.1.5 | ml |
| 67 | 12.1.6 | D= 200 mm | 2.75d | 2007-10-08 | 2007-10-10 | 66 | 155.18d | 0d | AYUDANTE; OFICIAL | 44h | 906,598 | 13-09 | 13 | 13.01 | 10.1.6 | ml |
| 68 | 12.1.7 | 0,60 * 0,60 | 2.1d | 2007-10-10 | 2007-10-12 | 67 | 155.18d | 0d | AYUDANTE; OFICIAL | 33.6h | 411,603 | 13-14 | 13 | 13.01 | 10.1.7 | un |
| 69 | 12.1.8 | 0,80 * 0,80 | 1.7d | 2007-10-12 | 2007-10-16 | 68 | 155.18d | 56.39d | AYUDANTE; OFICIAL | 27.2h | 403,990 | 13-15 | 13 | 13.01 | 10.1.8 | un |
| 70 | 13 | **INSTALACION HIDRAULICA PVC** | 25.5d | 2007-11-14 | 2007-12-19 |  | 117.75d |  |  | 12.72h | 195,937 | 14 | 14 | 14 | 11 |  |
| 71 | 13.1 | **INSTALACION HIDRAULICA PVC** | 25.5d | 2007-11-14 | 2007-12-19 |  | 117.75d |  |  | 12.72h | 195,937 | 14.01 | 14 | 14.01 | 11.1 |  |
| 72 | 13.1.1 | D= 3/4" | 2.5d | 2007-11-14 | 2007-11-16 | 23SS+15d | 117.75d | 0d | OFICIAL [10%]; AYUDANTE [20%] | 6h | 98,340 | 14-02 | 14 | 14.01 | 11.1.1 | ml |
| 73 | 13.1.2 | D= 1/2" | 4d | 2007-11-16 | 2007-11-22 | 72 | 117.75d | 0d | AYUDANTE [1%]; OFICIAL [1%] | 0.64h | 26,719 | 14-09 | 14 | 14.01 | 11.1.2 | un |
| 74 | 13.1.3 | Puntos hidraulicos 1/2 | 19d | 2007-11-22 | 2007-12-19 | 73 | 117.75d |  | AYUDANTE [2%]; OFICIAL [2%] | 6.08h | 70,878 | 14-17 | 14 | 14.01 | 11.1.3 | un |
| 75 | 14 | **AIRE ACONDICIONADO** | 31d | 2007-12-26 | 2008-02-07 |  | 3d |  |  | 906.72h | 42,272,001 | 15 | 15 | 15 | 12 |  |
| 76 | 14.1 | **AIRE ACONDICIONADO** | 31d | 2007-12-26 | 2008-02-07 |  | 3d |  |  | 906.72h | 42,272,001 | 15.01 | 15 | 15.01 | 12.1 |  |
| 77 | 14.1.1 | Suministro equipo de aire acondicionado tipo split | 8d | 2007-12-26 | 2008-01-07 | 94 | 3d | 0d | AYUDANTE [50%]; OFICIAL [50%] | 64h | 24,968,460 | 15-01 | 15 | 15.01 | 12.1.1 | un |
| 78 | 14.1.2 | Conductos del aire en lamina galvanizada | 7.6d | 2008-01-07 | 2008-01-17 | 77 | 87.12d | 0d | AYUDANTE; OFICIAL | 121.6h | 5,828,592 | 15-02 | 15 | 15.01 | 12.1.2 | un |
| 79 | 14.1.3 | Rejilla Suministro 18x8 | 1.6d | 2008-01-17 | 2008-01-18 | 78 | 87.12d | 0d | AYUDANTE; OFICIAL | 25.6h | 1,542,592 | 15-03 | 15 | 15.01 | 12.1.3 | un |
| 80 | 14.1.4 | Rejilla Retorno 24x12 | 0.4d | 2008-01-18 | 2008-01-21 | 79 | 87.12d | 0d | AYUDANTE; OFICIAL | 6.4h | 518,352 | 15-04 | 15 | 15.01 | 12.1.4 | un |
| 81 | 14.1.5 | Rejilla T.A.E. 14x12 | 0.4d | 2008-01-21 | 2008-01-21 | 80 | 87.12d | 0d | AYUDANTE; OFICIAL | 6.4h | 368,944 | 15-05 | 15 | 15.01 | 12.1.5 | un |
| 82 | 14.1.6 | Succion 1 1/8 aislada | 3.67d | 2008-01-21 | 2008-01-25 | 81 | 87.12d | 0d | AYUDANTE; OFICIAL | 58.72h | 2,743,796 | 15-06 | 15 | 15.01 | 12.1.6 |  |
| 83 | 14.1.7 | Liquido de 3/8" | 1.47d | 2008-01-25 | 2008-01-28 | 82 | 87.12d | 0d | AYUDANTE; OFICIAL | 23.52h | 750,376 | 15-07 | 15 | 15.01 | 12.1.7 |  |
| 84 | 14.1.8 | Filtro secador 3/8" | 0.4d | 2008-01-28 | 2008-01-29 | 83 | 87.12d | 0d | AYUDANTE; OFICIAL | 6.4h | 223,248 | 15-08 | 15 | 15.01 | 12.1.8 | un |
| 85 | 14.1.9 | Visor de liquido 3/8" | 0.4d | 2008-01-29 | 2008-01-29 | 84 | 87.12d | 0d | AYUDANTE; OFICIAL | 6.4h | 223,248 | 15-09 | 15 | 15.01 | 12.1.9 | un |
| 86 | 14.1.10 | Valvula de paso 3/8" | 0.53d | 2008-01-29 | 2008-01-30 | 85 | 87.12d | 0d | AYUDANTE; OFICIAL | 8.48h | 375,024 | 15-10 | 15 | 15.01 | 12.1.10 | un |
| 87 | 14.1.11 | Termostato | 0.4d | 2008-01-30 | 2008-01-30 | 86 | 87.12d | 0d | AYUDANTE; OFICIAL | 6.4h | 455,248 | 15-11 | 15 | 15.01 | 12.1.11 | un |
| 88 | 14.1.12 | Pulsador | 0.4d | 2008-01-30 | 2008-01-31 | 87 | 87.12d | 0d | AYUDANTE; OFICIAL | 6.4h | 385,648 | 15-12 | 15 | 15.01 | 12.1.12 | un |
| 89 | 14.1.13 | Soporte Metalico Unidad Manejadora | 0.4d | 2008-01-31 | 2008-01-31 | 88 | 87.12d |  | AYUDANTE; OFICIAL | 6.4h | 594,448 | 15-13 | 15 | 15.01 | 12.1.13 | un |
| 90 | 14.1.14 | Mano de Obra Instalacion | 28d | 2007-12-26 | 2008-02-04 | 77SS | 3d | 0d | AYUDANTE; OFICIAL | 448h | 2,635,220 | 15-14 | 15 | 15.01 | 12.1.14 | gl |
| 91 | 14.1.15 | Balanceo del aire | 7d | 2008-01-29 | 2008-02-07 | 90FS-4d | 81.79d | 0d | AYUDANTE; OFICIAL | 112h | 658,805 | 15-15 | 15 | 15.01 | 12.1.15 | gl |

| ID | WBS | Task | Type | Duration | Start | Finish | Predecessors | Total slack | Free slack | Resources | Work | Cost | Text2 | Text3 | Text4 | Text5 | Text1 |
| --- | --- | --- | --- | --- | --- | --- | --- | --- | --- | --- | --- | --- | --- | --- | --- | --- | --- |
| 92 | 15 | **REDES ELECTRICAS** |  | 2d | 2007-12-24 | 2007-12-26 |  | 3d |  |  | 53.44h | 4,691,470 | 13 | 16 | 16 | 16 |  |
| 93 | 15.1 | **REDES ELECTRICAS** |  | 2d | 2007-12-24 | 2007-12-26 |  | 3d |  |  | 53.44h | 4,691,470 | 13.1 | 16.01 | 16 | 16.01 |  |
| 94 | 15.1.1 | Acometida aire acondicionado salas de sistemas |  | 2d | 2007-12-24 | 2007-12-26 | 30 | 3d | 0d | AYUDANTE; OFICIAL [234%] | 53.44h | 4,691,470 | 13.1.1 | 16-30 | 16 | 16.01 | ml |
| 95 | 16 | FIN | milestone | 0d | 2008-02-07 | 2008-02-07 | 94, 91, 48, 43, 44 | 81.79d |  |  |  |  |  |  |  |  |  |
| 96 | 11 | FIN TOTAL | milestone | 0d | 2008-06-02 | 2008-06-02 | 95 | 0d |  |  |  |  |  |  |  |  |  |
